# FWD End Doors

Schedule from MS Project, 2001-10-18 to 2002-11-15, A marks actual dates.
SLAC

## Calendars

- Standard: Mon-Fri 08:00-12:00, 13:00-17:00; Sat-Sun off. Exceptions (off unless hours are given): 2001-12-22 to 2002-01-01, 2002-01-21, 2002-02-18, 2002-05-27, 2002-07-04, 2002-09-02.

## Resources

| Resource |
| --- |
| HC |
| IFRB |
| IFRT |
| ENG |
| MFD |
| PURCH |
| CRYO |
| ALIGN |
| ELECT |
| EMC |
| IFRG |
| PEP |
| SHE |
| IRB |
| CR |
| SEM |
| DIRC |
| ED |
| IFRR |
| DT |
| FE |
| FW |
| IFRH |
| BW |
| BE |
| IFRF |
| BP |
| DIFR |
| BIFR |
| FB |
| BB |
| Workshop |
| C. Carr |
| SJM |
| vac |
| BBR |
| P.Bong |
| SVT Tech |
| DC Tech |
| Riggers |
| C. Field |
| Jong Yi |
| S.Ecklund |
| C.Cheng |
| DC |
| IFRA |
| 10 |
| DCH |
| Util |
| BBR<BW |
| PC |

## Schedule

| ID | WBS | Task | Type | Duration | Start | Finish | Predecessors | Complete | Remaining | Total slack | Free slack | Constraint | Resources | Work | Actual work |
| --- | --- | --- | --- | --- | --- | --- | --- | --- | --- | --- | --- | --- | --- | --- | --- |
| 1 | 1 | **BABAR ENGINEERING & FABRICATION** |  | 213d | 2001-10-18 A | 2002-08-27 |  | 71% | 61.5d | 56.55d |  |  |  | 23328h | 16214.9h |
| 3 | 1.1 | **CHAMBER TESTING - RPCs** |  | 170d | 2001-11-13 A | 2002-07-23 |  | 85% | 25.76d | 81.55d |  |  |  | 1232h | 1032h |
| 4 | 1.1.1 | Begin Test Stand Setup (LLNL, Putallaz) |  | 1d | 2001-11-13 A | 2001-11-13 A |  | 100% |  |  |  |  |  |  |  |
| 5 | 1.1.2 | Clear CEH Floor |  | 2d | 2001-11-13 A | 2001-11-14 A |  | 100% |  |  |  |  | HC | 16h | 16h |
| 6 | 1.1.3 | Fab Test Stand Comps |  | 7d | 2001-11-13 A | 2001-11-21 A |  | 100% |  |  |  |  | HC | 56h | 56h |
| 7 | 1.1.4 | Install Test Stand Frames |  | 5d | 2001-11-22 A | 2001-11-28 A | 6 | 100% |  |  |  |  | HC | 40h | 40h |
| 8 | 1.1.5 | Install Dry Air and Safety Systems |  | 27d | 2001-11-29 A | 2002-01-15 A | 7 | 100% |  |  |  |  | HC | 216h | 216h |
| 9 | 1.1.6 | RPC Box 1 Arrives at SLAC |  | 1d | 2001-12-07 A | 2001-12-07 A |  | 100% |  |  |  | must start on 2001-12-07 |  |  |  |
| 10 | 1.1.7 | Finish Test Stand Setup in CEH |  | 5d | 2001-12-07 A | 2001-12-13 A | 9 | 100% |  |  |  |  | HC | 40h | 40h |
| 11 | 1.1.8 | Modify Test Stand & Fab New Fixtures |  | 19d | 2001-12-14 A | 2002-01-18 A | 10 | 100% |  |  |  |  | HC | 152h | 152h |
| 12 | 1.1.9 | Box 1 Chamber Testing |  | 38d | 2002-01-22 A | 2002-03-15 A | 11FS+5d, 8, 9 | 100% |  |  |  |  | IFRT | 304h | 304h |
| 13 | 1.1.10 | RPC Box 2 Arrives at SLAC |  | 1d | 2002-01-23 A | 2002-01-23 A | 9FS+27d | 100% |  |  |  |  |  |  |  |
| 14 | 1.1.11 | Box 2 Chamber Testing |  | 3d | 2002-03-21 A | 2002-03-25 A | 13, 12 | 100% |  |  |  |  | IFRT | 24h | 24h |
| 15 | 1.1.12 | RPC Box 3 Arrives at SLAC |  | 1d | 2002-02-12 A | 2002-02-12 A | 13FS+10d | 100% |  |  |  |  |  |  |  |
| 16 | 1.1.13 | Box 3 Chamber Testing |  | 5d | 2002-03-26 A | 2002-04-01 A | 14, 15 | 100% |  |  |  |  | IFRT | 40h | 40h |
| 17 | 1.1.14 | RPC Box 4 Arrives at Slac |  | 1d | 2002-03-21 A | 2002-03-21 A | 15FS+27d | 100% |  |  |  |  |  |  |  |
| 18 | 1.1.15 | Box 4 Chamber Testing |  | 4d | 2002-04-02 A | 2002-04-05 A | 17, 16 | 100% |  |  |  |  | IFRT | 32h | 32h |
| 19 | 1.1.16 | RPC Box 5 Arrives at SLAC |  | 1d | 2002-04-08 A | 2002-04-08 A | 17FS+15d | 100% |  |  |  |  |  |  |  |
| 20 | 1.1.17 | Box 5 Chamber Testing |  | 5d | 2002-04-15 A | 2002-04-19 A | 19, 18 | 100% |  |  |  |  | IFRT | 40h | 40h |
| 21 | 1.1.18 | RPC Box 6 Arrives at SLAC |  | 1d | 2002-05-01 A | 2002-05-01 A | 19FS+12d | 100% |  |  |  |  |  |  |  |
| 22 | 1.1.19 | Box 6 Chamber Testing |  | 9d | 2002-05-23 A | 2002-06-05 A | 21, 20 | 100% |  |  |  |  | IFRT | 72h | 72h |
| 23 | 1.1.20 | RPC Box 7 Arrives at SLAC |  | 1d | 2002-06-07 A | 2002-06-07 A | 21FS+6d | 100% |  |  |  |  |  |  |  |
| 24 | 1.1.21 | Box 7 Chamber Testing |  | 5d | 2002-06-10 | 2002-06-14 | 23, 22 |  |  | 88d | 6d |  | IFRT | 40h |  |
| 25 | 1.1.22 | RPC Box 8 Arrives at SLAC |  | 1d | 2002-06-24 A | 2002-06-24 A | 23FS+6d | 100% |  |  |  |  |  |  |  |
| 26 | 1.1.23 | Box 8 Chamber Testing |  | 5d | 2002-06-25 | 2002-07-01 | 25, 24 |  |  | 82d | 0d |  | IFRT | 40h |  |
| 27 | 1.1.24 | RPC Box 9 Arrives at SLAC |  | 1d | 2002-06-25 A | 2002-06-25 A | 25FS+10d | 100% |  |  |  |  |  |  |  |
| 28 | 1.1.25 | Box 9 Chamber Testing |  | 5d | 2002-07-02 | 2002-07-09 | 27, 26 |  |  | 82d | 0d |  | IFRT | 40h |  |
| 29 | 1.1.26 | RPC Box 10 Arrives at SLAC |  | 1d | 2002-07-02 A | 2002-07-02 A | 27FS+10d | 100% |  |  |  |  |  |  |  |
| 30 | 1.1.27 | Box 10 Chamber Testing |  | 5d | 2002-07-10 | 2002-07-16 | 29, 28 |  |  | 82d | 0d |  | IFRT | 40h |  |
| 31 | 1.1.28 | Belt RPCs Arrive at SLAC | milestone | 0d | 2002-07-16 | 2002-07-16 | 29FS+9d |  |  | 82d | 0d |  |  |  |  |
| 32 | 1.1.29 | Belt RPCs Testing |  | 5d | 2002-07-17 | 2002-07-23 | 31, 30 |  |  | 82d |  |  | IFRT | 40h |  |
| 33 | 1.1.30 | Chambers Ready for Pre-Assembly Preparation | milestone | 0d | 2002-07-16 | 2002-07-16 | 30 |  |  | 82d | 0d |  |  |  |  |

| ID | WBS | Task | Type | Duration | Start | Finish | Predecessors | Complete | Resources | Work | Actual work |
| --- | --- | --- | --- | --- | --- | --- | --- | --- | --- | --- | --- |
| 35 | 1.2 | **EARTHQUAKE ENGINEERING** |  | 26d | 2001-11-13 A | 2001-12-18 A |  | 100% |  | 200h | 200h |
| 36 | 1.2.1 | Earthquake Analysis Peer Review (Boyce) |  | 24d | 2001-11-13 A | 2001-12-14 A |  | 100% | ENG | 192h | 192h |
| 37 | 1.2.2 | EQ Committee Review |  | 1d | 2001-12-18 A | 2001-12-18 A | 36 | 100% | ENG | 8h | 8h |
| 38 | 1.2.3 | EQ Committee Approval |  | 1d | 2001-12-18 A | 2001-12-18 A | 37 | 100% |  |  |  |
| 40 | 1.3 | **FLUX BAR FIXT, GLEASON SUPTS, END DOOR FEET** |  | 155d | 2001-11-13 A | 2002-07-01 A |  | 100% |  | 1064h | 1064h |
| 41 | 1.3.1 | Design End Door Feet Mods (Boyce) |  | 23d | 2002-02-01 A | 2002-03-06 A | 71 | 100% | ENG | 184h | 184h |
| 42 | 1.3.2 | Design New Gleason Support (Putallaz) |  | 11d | 2002-02-01 A | 2002-02-15 A |  | 100% | ENG | 88h | 88h |
| 43 | 1.3.3 | Fab New Gleason Supports |  | 10d | 2002-03-25 A | 2002-04-05 A | 42FS+10d | 100% | HC | 80h | 80h |
| 44 | 1.3.4 | Gleason Supports Ready for Installation |  | 1d | 2002-04-05 A | 2002-04-05 A | 43 | 100% |  |  |  |
| 45 | 1.3.5 | Fab End Door Feet Mods |  | 79d | 2002-03-11 A | 2002-06-30 A | 41FS+10d | 100% | PURCH | 632h | 632h |
| 46 | 1.3.6 | End Door Feet Mods Ready for Installation |  | 1d | 2002-07-01 A | 2002-07-01 A | 45 | 100% |  |  |  |
| 47 | 1.3.7 | Fab Flux Bar Fixtures |  | 10d | 2001-11-13 A | 2001-11-26 A |  | 100% | HC | 80h | 80h |
| 48 | 1.3.8 | Flux Bar Fixtures Ready for Brass Absorber Inst. | milestone | 0d | 2001-11-26 A | 2001-11-26 A | 47 | 100% |  |  |  |
| 50 | 1.4 | **BRASS ABSORBER** |  | 109d | 2001-11-13 A | 2002-04-25 A |  | 100% |  | 1920h | 1920h |
| 51 | 1.4.1 | 16 Brass Plates Arrive at SLAC |  | 13d | 2001-11-13 A | 2001-11-29 A |  | 100% | PURCH | 104h | 104h |
| 52 | 1.4.2 | 4 Brass Plates Arrive at SLAC |  | 50d | 2001-11-29 A | 2002-02-19 A | 51 | 100% | PURCH | 400h | 400h |
| 53 | 1.4.3 | 10 Brass Plates Arrive at SLAC |  | 24d | 2002-02-19 A | 2002-03-22 A | 52 | 100% | PURCH | 192h | 192h |
| 54 | 1.4.4 | Brass Absorber Plates Ready for Installation | milestone | 0d | 2002-03-22 A | 2002-03-22 A | 53 | 100% |  |  |  |
| 55 | 1.4.5 | Design Brass Installation Fixture - Lower (Krebs) |  | 29d | 2001-11-13 A | 2001-12-21 A | 103 | 100% | ENG | 232h | 232h |
| 56 | 1.4.6 | Design Brass Installation Fixture - Mid (Krebs) |  | 20d | 2002-01-31 A | 2002-02-28 A | 122 | 100% | ENG | 160h | 160h |
| 57 | 1.4.7 | Design Brass Installation Fixture - Upper (Krebs) |  | 10d | 2002-02-14 A | 2002-02-28 A | 56 | 100% | ENG | 80h | 80h |
| 58 | 1.4.8 | Fab Brass Installation Fixture - Lower |  | 12d | 2002-01-07 A | 2002-01-23 A | 55 | 100% | MFD | 96h | 96h |
| 59 | 1.4.9 | Fab Brass Installation Fixture - Mid |  | 31d | 2002-03-01 A | 2002-04-12 A | 56 | 100% | MFD | 248h | 248h |
| 60 | 1.4.10 | Fab Brass Installation Fixture - Upper |  | 25d | 2002-03-01 A | 2002-04-04 A | 57 | 100% | MFD | 200h | 200h |
| 61 | 1.4.11 | Test Lower Fixture w/Mock Plate |  | 1d | 2002-01-25 A | 2002-01-25 A | 58 | 100% | HC | 8h | 8h |
| 62 | 1.4.12 | Test Mid Fixture w/Mock Plate |  | 1d | 2002-04-25 A | 2002-04-25 A | 59 | 100% | HC | 8h | 8h |
| 63 | 1.4.13 | Test Upper Fixture w/Mock Plate |  | 1d | 2002-04-08 A | 2002-04-08 A | 60 | 100% | HC | 8h | 8h |
| 64 | 1.4.14 | Design Brass Plate Staging Fixture (Krebs) |  | 8d | 2002-01-18 A | 2002-01-30 A |  | 100% | ENG | 64h | 64h |
| 65 | 1.4.15 | Fab Brass Plate Staging Fixture |  | 14d | 2002-01-30 A | 2002-02-19 A | 64 | 100% | HC | 112h | 112h |
| 66 | 1.4.16 | Test Staging Fixture with Mock Plate and Lower Fixture |  | 1d | 2002-02-21 A | 2002-02-21 A | 65 | 100% | HC | 8h | 8h |
| 67 | 1.4.17 | Brass Installation Fixtures Ready for Brass Abs. Inst. |  | 1d | 2002-04-25 A | 2002-04-25 A | 66, 63, 62 | 100% |  |  |  |

| ID | WBS | Task | Type | Duration | Start | Finish | Predecessors | Complete | Remaining | Total slack | Free slack | Constraint | Resources | Work | Actual work |
| --- | --- | --- | --- | --- | --- | --- | --- | --- | --- | --- | --- | --- | --- | --- | --- |
| 69 | 1.5 | **LAYER 18/19 STEEL ABSORBER** |  | 169d | 2001-11-13 A | 2002-07-22 |  | 82% | 29.73d | 82.55d |  |  |  | 1720h | 1416h |
| 70 | 1.5.1 | Design Layer 18/19 Absorber - Top & Mid (Boyce) |  | 50d | 2001-11-13 A | 2002-01-31 A |  | 100% |  |  |  |  | ENG | 400h | 400h |
| 71 | 1.5.2 | Design Layer 18/19 Absorber - Bottom (Boyce) |  | 21d | 2002-01-02 A | 2002-01-31 A |  | 100% |  |  |  |  | ENG | 168h | 168h |
| 72 | 1.5.3 | Fab of Layer 18/19 Housings |  | 106d | 2002-02-01 A | 2002-07-02 A | 71 | 100% |  |  |  |  | PURCH | 848h | 848h |
| 73 | 1.5.4 | Layer 18/19 Housings at SLAC |  | 1d | 2002-07-02 A | 2002-07-02 A | 72 | 100% |  |  |  |  |  |  |  |
| 74 | 1.5.5 | Paint Layer 18/19 Housings |  | 5d | 2002-07-03 | 2002-07-10 | 73 |  |  | 88d | 4d |  | HC | 40h |  |
| 75 | 1.5.5 | Layer 18/19 RPCs Ready for Insertion into Housings | milestone | 0d | 2002-07-16 | 2002-07-16 | 33 |  |  | 84d | 0d |  |  |  |  |
| 76 | 1.5.6 | Insert Layer 18/19 RPCs into Housings |  | 3d | 2002-07-17 | 2002-07-19 | 75, 74 |  |  | 84d | 0d |  | IFRB | 24h |  |
| 77 | 1.5.7 | Layer 18/19 Modules Ready for Installation | milestone | 0d | 2002-07-19 | 2002-07-19 | 76 |  |  | 84d |  |  |  |  |  |
| 78 | 1.5.9 | Design Mods to F-CAL Extraction System for EQ Clearance (Boyce) |  | 30d | 2002-06-10 A | 2002-07-22 |  |  | 30d | 83d |  | start no earlier than 2002-06-10 | ENG | 240h |  |
| 80 | 1.6 | **SUPER HEAT EXCHANGER** |  | 150d | 2002-01-02 A | 2002-08-05 |  | 66% | 51.14d | 72.55d |  |  | SHE | 7120h | 4710.91h |
| 81 | 1.6.1 | Design Super Heat Exchanger Support Platform |  | 32d | 2002-01-02 A | 2002-02-15 A |  | 100% |  |  |  | must start on 2002-01-02 | ENG; SHE | 256h | 256h |
| 82 | 1.6.2 | Fab Fluo Panel Jumper Pipes (Racine) |  | 17d | 2002-02-15 A | 2002-03-12 A |  | 100% |  |  |  | must start on 2002-02-12 | CRYO; SHE | 272h | 272h |
| 83 | 1.6.3 | Peer Review of Super Heat Exchanger Platform Earthquake Calcs (Dittert) |  | 26d | 2002-02-15 A | 2002-03-25 A | 81 | 100% |  |  |  |  | ENG; SHE | 416h | 416h |
| 84 | 1.6.4 | Earthquake Committee Approval of Super Heat Exchanger Platform Calcs |  | 1d | 2002-03-29 A | 2002-03-29 A | 83 | 100% |  |  |  |  | ENG; SHE | 16h | 16h |
| 85 | 1.6.5 | Design Super Heat Exchanger Fluorinert Valve Panel (Constable) |  | 73d | 2002-01-02 A | 2002-04-16 A |  | 100% |  |  |  | start no earlier than 2002-01-02 | ENG; SHE | 1168h | 1168h |
| 86 | 1.6.6 | Design Super Heat Exchanger Water Valve Panel (Constable) |  | 23d | 2002-03-15 A | 2002-04-16 A | 85 | 100% |  |  |  |  | ENG; SHE | 368h | 368h |
| 87 | 1.6.7 | Order Remaining Valves (Krebs) |  | 3d | 2002-04-17 A | 2002-04-19 A | 86 | 100% |  |  |  |  | ENG; SHE | 48h | 48h |
| 88 | 1.6.8 | Order Remaining Heat Exchanger Components (Constable) |  | 32d | 2002-04-17 A | 2002-05-31 A | 86 | 100% |  |  |  |  | ENG; SHE | 512h | 512h |
| 89 | 1.6.9 | Design Super Heat Exchanger Ass'y (Constable) |  | 25d | 2002-06-03 A | 2002-07-08 | 86 |  | 25d | 73d | 0d |  | ENG; SHE | 400h |  |
| 90 | 1.6.10 | Design Heat Exchanger Controls (Rodriguez) |  | 15d | 2002-04-22 A | 2002-05-10 |  |  | 15d | 0d |  | start no earlier than 2002-04-16 | ENG; SHE | 240h |  |
| 91 | 1.6.11 | Write Operational Procedures for Heat Exchanger (Shin) |  | 10d | 2002-06-03 | 2002-06-14 |  |  |  | 108d |  | start no earlier than 2002-06-03 | ENG; SHE | 160h |  |
| 92 | 1.6.12 | Fab Heat Exchanger Controls (Rodriguez) |  | 20d | 2002-05-13 A | 2002-06-10 | 90 |  | 20d | 112d |  |  | SHE | 160h |  |
| 93 | 1.6.13 | Fab Fluorinert Valve Panel Pre-fabs (Racine) |  | 15d | 2002-06-10 A | 2002-06-28 A | 87FS+20d | 100% |  |  |  |  | CRYO; SHE | 240h | 240h |
| 94 | 1.6.14 | Fab Water Valve Panel (Racine) |  | 28d | 2002-04-29 A | 2002-06-06 A | 93 | 100% |  |  |  |  | CRYO; SHE | 448h | 448h |
| 95 | 1.6.15 | Fab Super Heat Exchanger Support Platform (Contract) |  | 45d | 2002-04-29 A | 2002-07-01 | 84 |  | 45d | 97d |  |  | PURCH; SHE | 720h |  |
| 96 | 1.6.16 | Fab Support Platform North Column Components (MFD) |  | 11d | 2002-03-01 A | 2002-03-15 A | 84 | 100% |  |  |  |  | MFD; SHE | 176h | 176h |
| 97 | 1.6.17 | Fab Super Heat Exchanger Assembly (Putallaz) |  | 20d | 2002-07-09 | 2002-08-05 | 89 |  |  | 73d |  |  | HC; SHE | 320h |  |

| ID | WBS | Task | Type | Duration | Start | Finish | Predecessors | Complete | Remaining | Total slack | Free slack | Constraint | Resources | Work | Actual work |
| --- | --- | --- | --- | --- | --- | --- | --- | --- | --- | --- | --- | --- | --- | --- | --- |
| 99 | 1.7 | **CHAMBER BELT** |  | 170d | 2001-11-13 A | 2002-07-23 |  | 97% | 5.09d | 81.55d |  |  |  | 1872h | 1792h |
| 100 | 1.7.1 | Design Chamber Belt Housing Modules (Boyce, Sands, Fernholz) |  | 50d | 2001-11-13 A | 2002-01-31 A |  | 100% |  |  |  |  | ENG | 400h | 400h |
| 101 | 1.7.2 | Design Chamber Belt Installation Fixture Components (Krebs) |  | 3d | 2001-12-13 A | 2001-12-17 A |  | 100% |  |  |  | start no earlier than 2001-12-13 | ENG | 24h | 24h |
| 102 | 1.7.3 | Provide Flux Bar Mod Details for Chamber Belt Mounting (Sands) |  | 9d | 2002-02-01 A | 2002-02-13 A | 100 | 100% |  |  |  |  | ENG | 72h | 72h |
| 103 | 1.7.4 | Design Flux Bar Mods (Palrang) |  | 41d | 2002-04-11 A | 2002-06-07 A | 142 | 100% |  |  |  |  | ENG | 328h | 328h |
| 104 | 1.7.5 | Fab Chamber Belt Housing Modules (SLAC) |  | 84d | 2002-02-04 A | 2002-06-03 A | 100 | 100% |  |  |  |  | PURCH | 672h | 672h |
| 105 | 1.7.6 | Fab Chamber Belt Housing Modules (Princeton) |  | 100d | 2002-02-04 A | 2002-06-25 A | 100 | 100% |  |  |  |  |  |  |  |
| 106 | 1.7.6 | Fab Chamber Belt Inst Fixture Components |  | 37d | 2001-12-17 A | 2002-02-15 A |  | 100% |  |  |  |  | HC | 296h | 296h |
| 107 | 1.7.8 | Paint Chamber Belt Housings |  | 5d | 2002-06-21 A | 2002-06-27 | 104 |  | 5d | 99d |  |  | HC | 40h |  |
| 108 | 1.7.7 | Chamber Belt Housings Ready | milestone | 0d | 2002-06-03 | 2002-06-03 | 104 |  |  | 112d | 30d |  |  |  |  |
| 109 | 1.7.8 | Chamber Belt RPCs Ready for Insertion into Modules | milestone | 0d | 2002-07-16 | 2002-07-16 | 33 |  |  | 82d | 0d |  |  |  |  |
| 110 | 1.7.9 | Insert Chambers in Housings |  | 5d | 2002-07-17 | 2002-07-23 | 109, 108 |  |  | 82d | 0d |  | IFRB | 40h |  |
| 111 | 1.7.10 | Chamber Belt Modules Ready for Installation | milestone | 0d | 2002-07-23 | 2002-07-23 | 110 |  |  | 82d |  |  |  |  |  |
| 113 | 1.8 | **CHAMBER INSTALLATION FIXTURES** |  | 38d | 2002-03-11 A | 2002-05-01 A |  | 100% |  |  |  |  |  | 544h | 544h |
| 114 | 1.8.1 | Design Upper/Lower Chamber Installation Fixtures |  | 19d | 2002-03-11 A | 2002-04-04 A | 11FS+30d | 100% |  |  |  |  | ENG | 152h | 152h |
| 115 | 1.8.2 | Design Mid Chamber Installation Fixtures (Putallaz) |  | 19d | 2002-03-11 A | 2002-04-04 A | 114 | 100% |  |  |  |  | ENG | 152h | 152h |
| 116 | 1.8.3 | Fab Upper & Lower Chamber Installation Fixtures |  | 11d | 2002-04-05 A | 2002-04-19 A | 114 | 100% |  |  |  |  | HC | 88h | 88h |
| 117 | 1.8.4 | Fab Mid Chamber Installation Fixtures |  | 19d | 2002-04-05 A | 2002-05-01 A | 116 | 100% |  |  |  |  | HC | 152h | 152h |
| 118 | 1.8.5 | Chamber Fixtures Ready for Installation |  | 1d | 2002-05-01 A | 2002-05-01 A | 117 | 100% |  |  |  |  |  |  |  |
| 120 | 1.9 | **INSTALLATION PLATFORMS** |  | 176d | 2001-10-18 A | 2002-07-06 A |  | 100% |  |  |  |  |  | 1952h | 1952h |
| 121 | 1.9.1 | Design Installation Platforms (Krebs) |  | 49d | 2001-11-13 A | 2002-01-30 A |  | 100% |  |  |  |  | ENG | 392h | 392h |
| 122 | 1.9.2 | Design Platform Ladders (Krebs) |  | 67d | 2001-10-18 A | 2002-01-30 A |  | 100% |  |  |  |  | ENG | 536h | 536h |
| 123 | 1.9.3 | Design Platform Posts & Bracing (Krebs) |  | 5d | 2002-03-11 A | 2002-03-15 A | 137 | 100% |  |  |  |  | ENG | 40h | 40h |
| 124 | 1.9.4 | Design Platform Handrail Supports & Platform Lift Eyes (Krebs) |  | 2d | 2002-03-21 A | 2002-03-22 A | 123 | 100% |  |  |  |  | ENG | 16h | 16h |
| 125 | 1.9.5 | Fab Installation Platforms (External) |  | 28d | 2002-02-04 A | 2002-03-14 A | 121 | 100% |  |  |  |  | PURCH | 224h | 224h |
| 126 | 1.9.6 | Fab Platform Ladders |  | 36d | 2002-02-07 A | 2002-03-29 A | 122FS+5d | 100% |  |  |  |  | HC | 288h | 288h |
| 127 | 1.9.7 | Fab Platform Posts & Bracing |  | 10d | 2002-04-01 A | 2002-04-12 A | 123 | 100% |  |  |  |  | HC | 80h | 80h |
| 128 | 1.9.8 | Fab Platform Handrail Supports and Platform Lift Eyes |  | 4d | 2002-04-02 A | 2002-04-05 A | 124 | 100% |  |  |  |  | MFD | 32h | 32h |
| 129 | 1.9.9 | Trial Assembly and Strength Test of Installation Platforms |  | 12d | 2002-04-30 A | 2002-05-15 A | 125, 127, 126 | 100% |  |  |  |  | HC | 96h | 96h |
| 130 | 1.9.10 | Handrail Mods |  | 10d | 2002-05-07 A | 2002-05-20 A | 129 | 100% |  |  |  |  | HC | 80h | 80h |
| 131 | 1.9.11 | Disassembly & Paint |  | 4d | 2002-05-20 A | 2002-05-23 A | 130 | 100% |  |  |  |  | HC | 32h | 32h |
| 132 | 1.9.12 | Design Bracing to Stiffen Platforms (Krebs) |  | 3d | 2002-06-10 A | 2002-06-12 A |  | 100% |  |  |  | start no earlier than 2002-06-03 |  |  |  |
| 133 | 1.9.13 | Fab and Fit Additional Platform Bracing |  | 17d | 2002-06-12 A | 2002-07-06 A | 132 | 100% |  |  |  |  | HC | 136h | 136h |
| 134 | 1.9.14 | Installation Platforms Ready for Installation | milestone | 0d | 2002-07-06 A | 2002-07-06 A | 131 | 100% |  |  |  |  |  |  |  |

| ID | WBS | Task | Type | Duration | Start | Finish | Predecessors | Complete | Remaining | Total slack | Free slack | Constraint | Resources | Work | Actual work |
| --- | --- | --- | --- | --- | --- | --- | --- | --- | --- | --- | --- | --- | --- | --- | --- |
| 136 | 1.10 | **BARREL CHAMBER CUTTING EXPERIMENTS** |  | 91d | 2002-03-01 A | 2002-07-09 |  | 35% | 59.35d | 0d |  |  |  | 1104h | 384h |
| 137 | 1.10.1 | Design Mock Barrel Gap for Chamber Cutting Experiments (Krebs) |  | 4d | 2002-03-01 A | 2002-03-06 A | 57 | 100% |  |  |  |  | ENG | 32h | 32h |
| 138 | 1.10.2 | Develop Barrel Chamber Cutting Method (Skarppaas) |  | 90d | 2002-03-04 | 2002-07-09 |  |  |  | 0d |  | must start on 2002-03-04 | ENG | 720h |  |
| 139 | 1.10.3 | Fab Mock Barrel Gap |  | 44d | 2002-03-11 A | 2002-05-09 A | 137 | 100% |  |  |  |  | HC | 352h | 352h |
| 141 | 1.11 | **PLATFORM MODS** |  | 89d | 2002-03-25 A | 2002-07-29 |  | 81% | 16.95d | 77.55d |  |  |  | 664h | 536h |
| 142 | 1.11.1 | Design End Door Platform Mods (Krebs) |  | 8d | 2002-03-25 A | 2002-04-03 A | 124 | 100% |  |  |  |  | ENG | 64h | 64h |
| 143 | 1.11.2 | EQ Analysis (Dittert) |  | 5d | 2002-07-08 A | 2002-07-12 |  |  | 5d | 78d | 0d |  | ENG | 40h |  |
| 144 | 1.11.3 | Peer Review of EQ Analysis |  | 10d | 2002-07-15 | 2002-07-26 | 143 |  |  | 78d | 0d |  | ENG | 80h |  |
| 145 | 1.11.4 | EQ Committee Review |  | 1d | 2002-07-29 | 2002-07-29 | 144 |  |  | 78d | 0d |  | ENG | 8h |  |
| 146 | 1.11.5 | EQ Committee Approval for End Door Platform Mods | milestone | 0d | 2002-07-29 | 2002-07-29 | 145 |  |  | 78d |  |  |  |  |  |
| 147 | 1.11.6 | Fab End Door Platform Mod Components |  | 27d | 2002-04-04 A | 2002-05-10 A | 142 | 100% |  |  |  |  | PURCH | 216h | 216h |
| 148 | 1.11.7 | Fab End Door Tie Rods |  | 20d | 2002-04-04 A | 2002-05-01 A | 142 | 100% |  |  |  |  | PURCH | 160h | 160h |
| 149 | 1.11.8 | Platform Mods Ready (Design & New Components) |  | 1d | 2002-05-10 A | 2002-05-10 A | 147 | 100% |  |  |  |  |  |  |  |
| 150 | 1.11.9 | Design Mods to EH-to-East Platform Stairway (Krebs) |  | 2d | 2002-06-10 A | 2002-06-11 A | 103 | 100% |  |  |  |  | ENG | 16h | 16h |
| 151 | 1.11.10 | Fab Mods to EH-to-East Platform Stairway |  | 10d | 2002-06-12 A | 2002-06-25 A | 150 | 100% |  |  |  |  | HC | 80h | 80h |
| 153 | 1.12 | **CABLING & MINICRATE RACKS** |  | 158d | 2001-11-13 A | 2002-07-05 |  | 20% | 125.85d | 93.55d |  |  |  | 2280h | 464h |
| 154 | 1.12.1 | Determine HV Cable Routing (Boyce, Band) |  | 29d | 2001-11-13 | 2001-12-21 |  |  |  | 223d |  |  | ENG | 232h |  |
| 155 | 1.12.2 | RPC to Minicr Cable Routing, Lengths & Labels Determined |  | 50d | 2001-11-13 | 2002-01-31 |  |  |  | 202d |  |  | IFRB | 400h |  |
| 156 | 1.12.3 | Procure Cables |  | 58d | 2002-02-08 A | 2002-05-01 A | 155FS+5d | 100% |  |  |  |  | IFRB | 464h | 464h |
| 157 | 1.12.4 | Pre-Bundle Cables into Wiring Harnesses |  | 20d | 2002-05-02 | 2002-05-30 | 156 |  |  | 119d | 0d |  | IFRB | 160h |  |
| 158 | 1.12.5 | RPC to Minicrate Rack Cables Ready for Installation | milestone | 0d | 2002-05-30 | 2002-05-30 | 157 |  |  | 119d |  |  |  |  |  |
| 159 | 1.12.6 | Finalize Minicrate Rack Design and Cable Maps (Band,Rogers) |  | 83d | 2002-01-02 A | 2002-04-30 |  |  | 83d | 0d |  | must start on 2002-01-02 | ENG | 664h |  |
| 160 | 1.12.7 | Prepare Minicrate to FEE Crate, Scalers, & Trigger Cables, LV |  | 45d | 2002-05-02 | 2002-07-05 | 156 |  |  | 94d |  |  | IFRB | 360h |  |
| 162 | 1.13 | **CHAMBER PRE-INSTALLATION PREPARATION** |  | 20d | 2002-06-03 A | 2002-06-28 |  | 39% | 12.18d | 97.55d |  |  |  | 80h | 80h |
| 163 | 1.13.1 | Prepare RPCs for Installation |  | 20d | 2002-06-03 A | 2002-06-28 |  |  | 20d | 98d |  | start no earlier than 2002-06-03 |  |  |  |
| 164 | 1.13.2 | Load Pizzeria FWB |  | 3d | 2002-06-10 A | 2002-06-12 A | 163 | 100% |  |  |  |  |  |  |  |
| 165 | 1.13.3 | Load Pizzeria EWB |  | 0.25d | 2002-06-12 A | 2002-06-12 | 164 |  | 0.25d | 110.75d |  |  |  |  |  |
| 166 | 1.13.4 | Fab 2nd Crate Handling Fixture and Brackets |  | 10d | 2002-06-10 A | 2002-06-21 A |  | 100% |  |  |  | start no earlier than 2002-06-10 | HC | 80h | 80h |

| ID | WBS | Task | Type | Duration | Start | Finish | Predecessors | Complete | Remaining | Total slack | Free slack | Constraint | Resources | Work | Actual work |
| --- | --- | --- | --- | --- | --- | --- | --- | --- | --- | --- | --- | --- | --- | --- | --- |
| 168 | 1.14 | **GAS SYSTEM** |  | 166d | 2002-01-02 A | 2002-08-27 |  |  | 166d | 56.55d |  |  |  | 1136h |  |
| 169 | 1.14.1 | Design Gas System (Boyce, Sands, Fernholz) |  | 81d | 2002-01-02 A | 2002-04-26 |  |  | 81d | 24d |  |  | ENG | 648h |  |
| 170 | 1.14.2 | Fab & Purchase Gas System Components (Boyce) |  | 20d | 2002-06-03 A | 2002-06-28 | 169 |  | 20d | 57d | 0d |  | ENG | 160h |  |
| 171 | 1.14.3 | Test Gas System Components |  | 20d | 2002-07-01 | 2002-07-29 | 170 |  |  | 57d | 0d |  | IFRB | 160h |  |
| 172 | 1.14.4 | Gas System Comps Ready for Installation | milestone | 0d | 2002-07-29 | 2002-07-29 | 171 |  |  | 57d | 0d |  |  |  |  |
| 173 | 1.14.5 | Install AC Outlets in Mincrate Rack Standoff Frame |  | 1d | 2002-07-30 | 2002-07-30 | 172 |  |  | 57d | 0d |  | HC | 8h |  |
| 174 | 1.14.6 | Install Gas System Components in Minicrate Rack Standoff Frame |  | 10d | 2002-07-31 | 2002-08-13 | 173 |  |  | 57d | 0d |  | IFRB | 80h |  |
| 175 | 1.14.7 | Install Gas System Components in Minicrate Rack Top Hat Frame |  | 10d | 2002-08-14 | 2002-08-27 | 174 |  |  | 57d |  |  | IFRB | 80h |  |
| 177 | 1.15 | **HV SYSTEM** |  | 29d | 2002-05-06 A | 2002-06-14 A |  | 100% |  |  |  |  |  | 120h | 120h |
| 178 | 1.15.1 | Design End Door HV Box Mounting Hardware (Putallaz) |  | 5d | 2002-05-06 A | 2002-05-10 A | 169 | 100% |  |  |  |  | ENG | 40h | 40h |
| 179 | 1.15.2 | Fab End Door HV Box Mounting Hardware |  | 7d | 2002-05-11 A | 2002-05-21 A | 178 | 100% |  |  |  |  |  |  |  |
| 180 | 1.15.3 | Fab Barrel HV Boxes |  | 10d | 2002-06-03 A | 2002-06-14 A |  | 100% |  |  |  | start no earlier than 2002-05-29 | HC | 80h | 80h |
| 181 | 1.15.4 | HV Box Mtg Hardware Ready for Installation |  | 1d | 2002-06-14 A | 2002-06-14 A | 179 | 100% |  |  |  |  |  |  |  |
| 183 | 1.16 | **RACEWAYS** |  | 40d | 2002-05-13 | 2002-07-09 |  |  |  | 91.55d |  |  |  | 320h |  |
| 184 | 1.16.1 | Design End Door to Minicrate Raceways - Lower (Rogers) |  | 10d | 2002-05-13 | 2002-05-24 | 178 |  |  | 92d | 0d |  | ENG | 80h |  |
| 185 | 1.16.2 | Design End Door to Minicrate Raceways - Upper (Rogers) |  | 10d | 2002-05-28 | 2002-06-10 | 184 |  |  | 92d | 0d |  | ENG | 80h |  |
| 186 | 1.16.3 | Fab End Door to Minicrate Raceway Components |  | 20d | 2002-06-11 | 2002-07-09 | 185 |  |  | 92d | 0d |  | PURCH | 160h |  |
| 187 | 1.16.4 | Raceway Components Ready for Installation | milestone | 0d | 2002-07-09 | 2002-07-09 | 186 |  |  | 92d |  |  |  |  |  |
| 189 | 2 | **PEP PREPARATION** |  | 179d | 2001-11-13 A | 2002-08-05 |  |  | 179d | 72.55d |  |  | PEP | 4072h | 112h |
| 190 | 2.1 | Make New SVT Crane Brackets |  | 10d | 2001-11-13 | 2001-11-26 |  |  |  | 241.55d |  |  | PEP; MFD | 80h |  |
| 191 | 2.2 | Design New Temporary Forward Support for ST |  | 14d | 2001-11-13 | 2001-11-30 |  |  |  | 101.75d | 0d |  | PEP; C. Carr | 112h |  |
| 192 | 2.3 | Manufacture Temp Support |  | 61d | 2001-11-30 | 2002-03-08 | 191 |  |  | 101.75d | 97.85d |  | PEP; MFD | 488h |  |
| 193 | 2.4 | Order Missing Fasteners on Fixture List |  | 10d | 2002-06-25 | 2002-07-09 |  |  |  | 21.5d | 19d | start no earlier than 2002-06-25 | PEP; SJM | 160h |  |
| 194 | 2.5 | Refurbish ST Fixtures |  | 20d | 2002-06-24 | 2002-07-22 |  |  |  | 12.5d | 10d | start no earlier than 2002-06-24 | PEP; MFD | 320h |  |
| 195 | 2.6 | Manufacture missing ST Fixtures |  | 25d | 2002-07-01 | 2002-08-05 |  |  |  | 2.5d | 0d | start no earlier than 2002-07-01 | MFD; PEP | 400h |  |
| 196 | 2.6 | Creat List of Required Vac Seals & Other Consumables |  | 5d | 2002-06-24 | 2002-06-28 |  |  |  | 62.25d | 0d | start no earlier than 2002-06-24 | PEP; SJM | 80h |  |
| 197 | 2.7 | Order New Vac Seals & Consumables as Required |  | 20d | 2002-07-01 | 2002-07-29 | 196 |  |  | 62.25d | 58.6d |  | PEP; MFD | 320h |  |
| 198 | 2.8 | Design New Forward Raft Support Plate |  | 40d | 2001-11-30 | 2002-02-06 | 191 |  |  | 131.5d | 0d |  | PEP; C. Carr | 320h |  |
| 199 | 2.9 | Manufacture New Forward Raft Support Plate |  | 40d | 2002-02-07 | 2002-04-04 | 198 |  |  | 131.5d | 129.1d |  | PEP; MFD | 640h |  |
| 200 | 2.11 | Prepare Clean Room in B31 for Support Tube work |  | 24d | 2002-07-02 | 2002-08-05 |  |  |  | 2.5d | 0d | start no earlier than 2002-07-02 | PEP; MFD | 384h |  |

| ID | WBS | Task | Type | Duration | Start | Finish | Predecessors | Complete | Remaining | Total slack | Free slack | Constraint | Resources | Work | Actual work |
| --- | --- | --- | --- | --- | --- | --- | --- | --- | --- | --- | --- | --- | --- | --- | --- |
| 202 | 3 | **SUMMER SHUTDOWN** |  | 97.55d | 2002-07-01 A | 2002-11-15 |  | 11% | 86.57d | 0d |  |  |  | 37654.5h | 4149.49h |
| 204 | 3.1 | End PEP Run | milestone | 0d | 2002-07-01 | 2002-07-01 |  |  |  | 0d |  | must start on 2002-07-01 | PEP; BBR |  |  |
| 205 | 3.2 | **Preliminary work** |  | 3.5d | 2002-07-01 | 2002-07-05 |  |  |  | 10.4d |  |  |  | 94.4h |  |
| 206 | 3.2.1 | Survey Beamlines From FWD Frangible Link to -15m Valve |  | 3d | 2002-07-01 | 2002-07-03 | 204 |  |  | 7.85d | 0d |  | ALIGN; PEP; BBR | 72h |  |
| 207 | 3.2.2 | Open IR-2 Curtain Wall |  | 0.1d | 2002-07-05 | 2002-07-05 | 206 |  |  | 94.05d | 0d |  | HC; CR; PEP; BBR | 3.2h |  |
| 208 | 3.2.3 | Remove DIRC Cyl, Lead and BWD End Plug & Wedges |  | 0.4d | 2002-07-05 | 2002-07-05 | 207 |  |  | 94.05d |  |  | HC; CR; DT; PEP; BB; BBR | 19.2h |  |
| 210 | 3.3 | **BABAR WORK, PHASE 1 (Pre ST Removal)** |  | 69d | 2002-07-01 A | 2002-10-07 |  | 24% | 52.1d | 28.55d |  |  | BBR; PEP | 16838.4h | 4149.49h |
| 211 | 3.3.1 | **End Doors, BaBar Mech Support, Remove Steel for IFR Upgrade** |  | 69d | 2002-07-01 | 2002-10-07 |  |  |  | 18.9d |  |  |  | 5047.2h |  |
| 212 | 3.3.1.1 | FWD End Door Closed - West |  | 1d | 2002-07-01 | 2002-07-01 | 204 |  |  | 96.55d |  |  | ED; FW; BBR | 24h |  |
| 213 | 3.3.1.2 | FWD End Door Closed - East |  | 1d | 2002-07-01 | 2002-07-01 | 204 |  |  | 96.55d |  |  | ED; FE; BBR | 24h |  |
| 214 | 3.3.1.3 | BWD End Door Closed - West |  | 1d | 2002-07-01 | 2002-07-01 | 204 |  |  | 96.55d |  |  | ED; BW; BBR | 24h |  |
| 215 | 3.3.1.4 | BWD End Door Closed - East |  | 1d | 2002-07-01 | 2002-07-01 | 204 |  |  | 96.55d |  |  | ED; BE; BBR | 24h |  |
| 216 | 3.3.1.5 | Untorq End Door Bolts |  | 1d | 2002-07-05 | 2002-07-05 | 206 |  |  | 75.55d | 0d |  | ED; BE; BW; FE; FW; HC; BBR | 56h |  |
| 217 | 3.3.1.6 | Open FWD End Door East (EMC CT Meas,Gap Plates) |  | 1d | 2002-07-08 | 2002-07-08 | 216 |  |  | 75.55d | 0d |  | ED; FE; HC; BBR | 32h |  |
| 218 | 3.3.1.7 | Insert Manlift 1 - FWD East |  | 1d | 2002-07-09 | 2002-07-09 | 217 |  |  | 75.55d | 0d |  | ED; FE; HC; CR; BBR | 40h |  |
| 219 | 3.3.1.8 | Remove 10 Shield Wall Blocks |  | 1d | 2002-07-10 | 2002-07-10 | 218 |  |  | 90.55d |  |  | HC; CR; BBR; PEP | 32h |  |
| 220 | 3.5.8.1 | Remove Upper Tie Rods - FWD West | milestone | 0d | 2002-07-09 | 2002-07-09 | 218 |  |  | 75.55d | 0d |  | ED; FW; HC; BBR |  |  |
| 221 | 3.3.1.10 | Remove Upper Flux Bar - FWD West |  | 1d | 2002-07-10 | 2002-07-10 | 220 |  |  | 75.55d | 0d |  | HC; CR; FW; BBR | 32h |  |
| 222 | 3.5.8.2 | Remove Upper Tie Rods - FWD East | milestone | 0d | 2002-07-10 | 2002-07-10 | 221 |  |  | 75.55d | 0d |  | ED; FE; HC; BBR |  |  |
| 223 | 3.3.1.12 | Remove Upper Flux Bar - FWD East |  | 1d | 2002-07-11 | 2002-07-11 | 222 |  |  | 75.55d | 0d |  | HC; CR; FE; BBR | 32h |  |
| 224 | 3.3.1.13 | Rem Ins & Lead Drs Over Gaps - FWD West |  | 3d | 2002-07-12 | 2002-07-16 | 223 |  |  | 75.55d | 0d |  | HC; FW; DIFR; BBR | 96h |  |
| 225 | 3.3.1.14 | Rem Ins & Lead Drs Over Gaps - FWD East |  | 3d | 2002-07-17 | 2002-07-19 | 224 |  |  | 75.55d | 0d |  | HC; FE; DIFR; BBR | 96h |  |
| 226 | 3.3.1.15 | Remove LV Racks |  | 2d | 2002-07-22 | 2002-07-23 | 225, 327 |  |  | 75.55d | 0d |  | HC; CR; FE; FW; DIFR; BBR | 96h |  |
| 227 | 3.3.1.16 | Transport Top Flux Bars to Shop |  | 6d | 2002-07-24 | 2002-07-31 | 226 |  |  | 75.55d |  |  | HC; BBR | 96h |  |
| 228 | 3.3.1.17 | Open BWD West End Door (Gap Plates,EMC CT Meas) |  | 1d | 2002-07-10 | 2002-07-10 |  |  |  | 89.55d | 0d | start no earlier than 2002-07-10 | HC; BW; BBR | 24h |  |
| 229 | 3.5.7.12 | Remove Gap Filler Plate - BWD West Lwr | milestone | 0d | 2002-07-10 | 2002-07-10 | 228 |  |  | 89.55d | 0d |  | HC; CR; BW; BIFR; BBR |  |  |
| 230 | 3.3.1.19 | Insert Manlift 2 - BWD West |  | 1d | 2002-07-11 | 2002-07-11 | 229 |  |  | 89.55d | 0d |  | HC; CR; BW; BIFR; BBR | 40h |  |
| 231 | 3.5.7.14 | Remove Gap Filler Plates - BWD West Upr | milestone | 0d | 2002-07-11 | 2002-07-11 | 230 |  |  | 89.55d |  |  | HC; CR; BW; BIFR; BBR |  |  |
| 232 | 3.5.7.8 | Remove Gap Filler Plates - FWD Upr East |  | 1d | 2002-07-11 | 2002-07-11 |  |  |  | 79.55d | 0d | start no earlier than 2002-07-11 | HC; CR; IFRF; FW; BIFR; BBR | 48h |  |
| 233 | 3.3.1.22 | Install EH-to-East Platform Stairway |  | 1d | 2002-07-12 | 2002-07-12 | 232 |  |  | 79.55d | 0d |  | HC; CR; BBR | 24h |  |
| 234 | 3.3.1.23 | Remove Manlift 1 - FWD East |  | 1d | 2002-07-15 | 2002-07-15 | 233 |  |  | 79.55d | 0d |  | HC; CR; BIFR; FW; BBR | 40h |  |
| 235 | 3.5.7.7 | Remove Gap Filler Plate - FWD Lwr East |  | 1d | 2002-07-16 | 2002-07-16 | 234 |  |  | 79.55d | 0d |  | HC; CR; IFRF; FW; BIFR; BBR | 48h |  |
| 236 | 3.3.1.25 | Drain Hoses/Remove Flux Bar Cooling Loops - FWD East |  | 7d | 2002-07-17 | 2002-07-25 | 235 |  |  | 79.55d |  |  | HC; DIFR; FW; BBR | 224h |  |
| 237 | 3.3.1.26 | Remove Upper Platform - East |  | 1d | 2002-07-12 | 2002-07-12 |  |  |  | 80.55d | 0d | start no earlier than 2002-07-12 | HC; CR; FE; DIFR | 32h |  |
| 238 | 3.3.1.27 | Remove Flux Bar 2 - East |  | 1d | 2002-07-15 | 2002-07-15 | 237 |  |  | 80.55d | 0d |  | HC; CR; FE; DIFR | 32h |  |
| 239 | 3.3.1.28 | Remove Flux Bar 1 - East |  | 1d | 2002-07-16 | 2002-07-16 | 238 |  |  | 80.55d | 0d |  | HC; CR; FE; DIFR | 32h |  |
| 240 | 3.3.1.29 | Close FWD East End Door (Barrel IFR HV) |  | 1d | 2002-07-17 | 2002-07-17 | 239 |  |  | 84.55d | 0d |  | HC; BBR; BIFR; FE | 32h |  |
| 241 | 3.3.1.30 | Open FWD West End Door (Gap Plates,Flux Bars,EMC CT Meas) |  | 1d | 2002-07-18 | 2002-07-18 | 240 |  |  | 84.55d |  |  | HC; FW; BBR; BIFR | 32h |  |
| 242 | 3.3.1.31 | Remove Gap Filler Plates - FWD Lwr West |  | 2d | 2002-07-15 | 2002-07-16 |  |  |  | 74.45d | 0d | start no earlier than 2002-07-15 | HC; CR; FW; BIFR; BBR | 80h |  |
| 243 | 3.3.1.32 | Insert Manlift 1 - FWD West |  | 1d | 2002-07-17 | 2002-07-17 | 242 |  |  | 74.45d | 0d |  | HC; CR; FW; BBR; EMC | 40h |  |
| 244 | 3.3.1.33 | Remove Gap Filler Plates - FWD Upr West |  | 1d | 2002-07-18 | 2002-07-18 | 243 |  |  | 74.45d | 0d |  | HC; CR; FW; BIFR; BBR | 40h |  |
| 245 | 3.3.1.34 | Drain Hoses/Remove Flux Bar Cooling Loops - FWD West |  | 4d | 2002-07-19 | 2002-07-24 | 244 |  |  | 74.45d | 0d |  | HC; DIFR; FW; BBR | 128h |  |
| 246 | 3.3.1.35 | Transport Upr East Flux Bars to Shop |  | 1d | 2002-07-25 | 2002-07-25 | 245 |  |  | 74.45d | 0d |  | HC; DIFR; CR; BBR | 32h |  |
| 247 | 3.3.1.36 | Close BWD West End Door (Barrel IFR Gas) |  | 1d | 2002-07-26 | 2002-07-26 | 246 |  |  | 78.55d |  |  | HC; BBR; BIFR | 24h |  |
| 248 | 3.3.1.37 | Remove Upper Platform - West |  | 1d | 2002-07-16 | 2002-07-16 |  |  |  | 83.55d | 0d | start no earlier than 2002-07-16 | HC; CR; FW; DIFR; BBR | 40h |  |
| 249 | 3.3.1.38 | Remove Upper Walkway - Southwest |  | 1d | 2002-07-17 | 2002-07-17 | 248 |  |  | 83.55d | 0d |  | HC; CR; FW; DIFR; BBR | 40h |  |
| 250 | 3.3.1.39 | Modify Upper Walkway - Southwest |  | 1d | 2002-07-18 | 2002-07-18 | 249 |  |  | 83.55d | 0d |  | HC; DIFR; BBR | 24h |  |
| 251 | 3.3.1.40 | Remove Flux Bar 2 - West |  | 1d | 2002-07-19 | 2002-07-19 | 250 |  |  | 83.55d |  |  | HC; CR; FW; DIFR; BBR | 40h |  |
| 252 | 3.3.1.41 | Open Bwd East End Door (Gap Plates,EMC CT Meas) |  | 1d | 2002-07-17 | 2002-07-17 |  |  |  | 64.75d | 0d | start no earlier than 2002-07-17 | HC; BE; BIFR; BBR | 32h |  |
| 253 | 3.3.1.42 | Remove Gap Filler Plates - Lwr BWD East |  | 1d | 2002-07-18 | 2002-07-18 | 252 |  |  | 64.75d | 0d |  | HC; CR; BIFR; BBR; BE | 40h |  |
| 254 | 3.3.1.43 | Insert EQ Baces - Lwr BWD East |  | 1d | 2002-07-19 | 2002-07-19 | 253 |  |  | 64.75d | 0d |  | HC; CR; BE; BBR | 32h |  |
| 255 | 3.3.1.44 | Insert Manlift 3 - BWD East |  | 1d | 2002-07-22 | 2002-07-22 | 254 |  |  | 64.75d | 0d |  | HC; CR; BE; BBR | 32h |  |
| 256 | 3.3.1.45 | Remove Gap Filler Plates - Upr BWD East |  | 1d | 2002-07-23 | 2002-07-23 | 255 |  |  | 64.75d | 0d |  | HC; CR; BE; BIFR; BBR | 40h |  |
| 257 | 3.3.1.46 | Insert EQ Braces - Upr BWD East |  | 1d | 2002-07-24 | 2002-07-24 | 256 |  |  | 64.75d | 0d |  | HC; CR; BE; BBR | 32h |  |
| 258 | 3.3.1.47 | Remove Flux Bar 1 - West |  | 1d | 2002-07-25 | 2002-07-25 | 257 |  |  | 64.75d | 0d |  | HC; CR; FW; DIFR; BBR | 40h |  |
| 259 | 3.3.1.48 | Remove Lead Bricks from Blue F-CAL Extraction Frames |  | 9d | 2002-07-26 | 2002-08-07 | 258 |  |  | 64.75d | 0d |  | HC; CR; FB; BBR; DIFR | 360h |  |
| 260 | 3.3.1.49 | Remove Blue F-CAL Extraction Frames |  | 1d | 2002-08-08 | 2002-08-08 | 259 |  |  | 64.75d | 0d |  | HC; CR; FB; DIFR; BBR | 40h |  |
| 261 | 3.3.1.50 | Remove SW Stair - Middle |  | 1d | 2002-08-09 | 2002-08-09 | 260 |  |  | 64.75d | 0d |  | HC; CR; FW; DIFR; BBR | 40h |  |
| 262 | 3.3.1.51 | Transport Upr West Flux Bars to Shop |  | 1d | 2002-08-12 | 2002-08-12 | 261 |  |  | 64.75d | 0d |  | HC; DIFR; CR; BBR | 32h |  |
| 263 | 3.5.8.3 | Replace Gap Filler Plate Helicoils - BWD East |  | 0.3d | 2002-08-13 | 2002-08-13 | 262 |  |  | 64.75d | 0d |  | HC; BE; BBR | 7.2h |  |
| 264 | 3.5.11.26 | Remove Upper Walkway - Southeast |  | 1d | 2002-08-13 | 2002-08-14 | 263 |  |  | 66.25d |  |  | HC; CR; FE; DIFR; BBR | 40h |  |
| 265 | 3.3.1.54 | Open FWD End Door East |  | 1d | 2002-07-23 | 2002-07-23 |  |  |  | 3.9d | 0d | start no earlier than 2002-07-23 | HC; PEP; BBR; FE | 32h |  |
| 266 | 3.5.11.34 | Remove Flux Bar 4 - West |  | 13d | 2002-07-23 | 2002-08-08 |  |  |  | 63.55d | 0d | start no earlier than 2002-07-23 | HC; CR; FW; DIFR; BBR | 520h |  |
| 267 | 3.5.11.35 | Remove Flux Bar 3 - West |  | 1d | 2002-08-09 | 2002-08-09 | 266 |  |  | 63.55d | 0d |  | HC; CR; FW; DIFR; BBR | 40h |  |
| 268 | 3.3.1.57 | Open BWD End Door West (DIRC DFBs) |  | 1d | 2002-07-24 | 2002-07-24 |  |  |  | 80.55d |  | start no earlier than 2002-07-24 | HC; BW; ED; DIRC; BBR | 40h |  |
| 269 | 3.3.1.58 | Transport Lwr West Flux Bars to Shop |  | 1d | 2002-09-09 | 2002-09-09 | 365 |  |  | 48.55d |  |  | HC; CR; DIFR; BBR | 32h |  |
| 270 | 3.5.11.36 | Remove Flux Bar 4 - East |  | 11d | 2002-09-09 | 2002-09-23 | 365 |  |  | 28.55d | 0d |  | HC; CR; FE; DIFR; BBR | 440h |  |
| 271 | 3.5.11.37 | Remove Flux Bar 3 - East |  | 5d | 2002-09-24 | 2002-09-30 | 270 |  |  | 28.55d | 0d |  | HC; CR; FE; DIFR; BBR | 200h |  |
| 272 | 3.5.11.38 | Drill and Tap Skid Plates for Lower Belt Chamber Modules |  | 1d | 2002-09-24 | 2002-09-24 | 270 |  |  | 34.55d | 0d |  | HC; FE; FW; DIFR; BBR | 40h |  |
| 273 | 3.5.11.39 | Install Temporary Gleason Support - East |  | 1d | 2002-10-03 | 2002-10-03 | 363, 272 |  |  | 28.55d | 0d |  | HC; FW; DIFR; BBR | 32h |  |

| ID | WBS | Task | Duration | Start | Finish | Predecessors | Complete | Remaining | Total slack | Free slack | Constraint | Resources | Work | Actual work |
| --- | --- | --- | --- | --- | --- | --- | --- | --- | --- | --- | --- | --- | --- | --- |
| 274 | 3.5.11.40 | Install Temporary Gleason Support - West | 1d | 2002-10-04 | 2002-10-04 | 273 |  |  | 28.55d | 0d |  | HC; FE; DIFR; BBR | 32h |  |
| 275 | 3.3.1.64 | Transport Lwr East Flux Bars to Shop | 1d | 2002-10-07 | 2002-10-07 | 274 |  |  | 28.55d |  |  | HC; CR; DIFR; BBR | 32h |  |
| 276 | 3.5.11.42 | Remove Layer 18 Assembly - East | 1d | 2002-09-25 | 2002-09-25 | 272 |  |  | 34.55d | 0d |  | HC; CR; FW; DIFR; BBR | 40h |  |
| 277 | 3.3.1.66 | Remove Manlift 2 - BWD West | 1d | 2002-09-26 | 2002-09-26 | 276 |  |  | 34.55d | 0d |  | HC; CR; BBR | 24h |  |
| 278 | 3.3.1.67 | Close BWD End Door West (Barrel IFR HV) | 1d | 2002-09-27 | 2002-09-27 | 277 |  |  | 34.55d |  |  | HC; BIFR; BBR | 24h |  |
| 279 | 3.5.11.43 | Remove Layer 18 Assembly - West | 1d | 2002-09-26 | 2002-09-26 | 276 |  |  | 35.55d |  |  | HC; CR; FE; DIFR; BBR | 40h |  |
| 280 | 3.5.11.44 | Clean Up Door Face - East | 10d | 2002-07-29 | 2002-08-09 |  |  |  | 58.55d | 0d | start no earlier than 2002-07-29 | HC; FW; DIFR; BBR | 320h |  |
| 281 | 3.5.11.45 | Clean Up Door Face - West | 10d | 2002-08-12 | 2002-08-23 | 280 |  |  | 58.55d |  |  | HC; FE; DIFR; BBR | 320h |  |
| 282 | 3.3.1.71 | Install EQ Braces - FWD West | 1d | 2002-08-12 | 2002-08-12 | 280 |  |  | 67.55d |  |  | HC; CR; BBR | 24h |  |
| 283 | 3.3.1.72 | Open BWD End Door - West (Barrel IFR HV) | 1d | 2002-08-06 | 2002-08-06 |  |  |  | 68.55d | 0d | start no earlier than 2002-08-06 | HC; BW; BIFR; BBR | 32h |  |
| 284 | 3.3.1.73 | Install EQ Brace - BWD Lwr West | 1d | 2002-08-07 | 2002-08-07 | 283 |  |  | 68.55d | 0d |  | HC; CR; BW; BBR | 32h |  |
| 285 | 3.3.1.74 | Insert Manlift 2 - BWD West | 1d | 2002-08-08 | 2002-08-08 | 284 |  |  | 68.55d | 0d |  | HC; CR; BW; BBR | 32h |  |
| 286 | 3.3.1.75 | Install EQ Brace - BWD Upr West | 1d | 2002-08-09 | 2002-08-09 | 285 |  |  | 68.55d |  |  | HC; CR; BW; BBR | 32h |  |
| 287 | 3.3.1.76 | Remove Upr EQ Braces - BWD East | 1d | 2002-08-07 | 2002-08-07 |  |  |  | 67.55d | 0d | start no earlier than 2002-08-07 | HC; CR; BBR | 24h |  |
| 288 | 3.3.1.77 | Remove Manlift 3 - BWD East | 1d | 2002-08-08 | 2002-08-08 | 287 |  |  | 67.55d | 0d |  | HC; CR; BE; BBR | 32h |  |
| 289 | 3.3.1.78 | Remove Lwr EQ Braces - BWD East | 1d | 2002-08-09 | 2002-08-09 | 288 |  |  | 67.55d | 0d |  | HC; CR; BE; BBR | 32h |  |
| 290 | 3.3.1.79 | Close BWD End Door East | 1d | 2002-08-12 | 2002-08-12 | 289 |  |  | 67.55d |  |  | HC; BE; BBR; BIFR | 32h |  |
| 291 | 3.3.2 | **Cryo Work** | 2d | 2002-07-05 | 2002-07-08 |  |  |  | 92.55d |  |  |  | 32h |  |
| 292 | 3.3.2.1 | Modify Dump Resistor Access Platform | 1d | 2002-07-05 | 2002-07-05 | 206 |  |  | 92.55d | 0d |  | HC; CRYO; BBR | 24h |  |
| 293 | 3.3.2.2 | Remove Magnet Dump Contactors | 1d | 2002-07-08 | 2002-07-08 | 292 |  |  | 92.55d |  | start no earlier than 2002-07-08 | CRYO | 8h |  |
| 294 | 3.3.3 | **Super Heat Exchanger** | 48d | 2002-07-02 A | 2002-09-09 |  | 58% | 20.09d | 48.55d |  |  | SHE; BBR | 2024h | 1110.51h |
| 295 | 3.3.3.1 | Drain Fluorinert System - Remove Valve Panel - Install Jumper Pipies (Racine) | 1d | 2002-07-02 A | 2002-07-02 A |  | 100% |  |  |  | start no earlier than 2002-07-02 | CRYO; SHE; CR; BBR | 32h | 32h |
| 296 | 3.3.3.2 | Modify Fluorinert Valve Panel (Racine) | 16d | 2002-07-03 A | 2002-07-25 A | 295 | 100% |  |  |  |  | CRYO; SHE; BBR | 384h | 384h |
| 297 | 3.3.3.3 | Reinstall Fluorinert Valve Panel & Make Fluo Connections (Racine) | 1d | 2002-07-26 A | 2002-07-26 A |  | 100% |  |  |  | start no earlier than 2002-07-24 | CRYO; SHE; CR; BBR | 32h | 32h |
| 298 | 3.3.3.4 | Test EMC Fluorinert Circuit | 1d | 2002-07-26 A | 2002-07-26 A | 297 | 100% |  |  |  |  | SHE; BBR; EMC | 24h | 24h |
| 299 | 3.3.3.5 | Make Piping Connections from DCH Cooling Circuits to Fluo Valve Panel (Racine) | 5d | 2002-08-29 A | 2002-09-05 A | 297 | 100% |  |  |  |  | CRYO; SHE; BBR; DC | 160h | 160h |
| 300 | 3.3.3.6 | Test Drift Chamber Water Circuits | 2d | 2002-09-06 | 2002-09-09 | 299 |  |  | 48.55d |  |  | SHE; DC; BBR | 48h |  |
| 301 | 3.3.3.7 | Install Backup Heat Exchanger Water Valve Panel (Racine) | 1d | 2002-08-06 A | 2002-08-06 A | 299 | 100% |  |  |  |  | CRYO; SHE; CR; BBR | 32h | 32h |
| 302 | 3.3.3.8 | Make Piping Connections from Fluo Valve Panel to Water Valve Panel (Racine) | 2d | 2002-08-07 | 2002-08-08 | 301 |  |  | 42.55d | 0d |  | CRYO; SHE; BBR | 48h |  |
| 303 | 3.3.3.9 | Make Piping Connections from DIRC/EMC Water Circuits to Water Valve Panel | 10d | 2002-08-09 | 2002-08-22 | 302 |  |  | 42.55d | 0d |  | CRYO; SHE; DIRC; EMC; BBR | 400h |  |
| 304 | 3.3.3.10 | Test DIRC Water Circuit | 2d | 2002-08-23 | 2002-08-26 | 303 |  |  | 57.55d |  |  | SHE; DIRC; BBR | 48h |  |
| 305 | 3.3.3.11 | Test EMC Water Circuit | 2d | 2002-08-23 | 2002-08-26 | 303 |  |  | 57.55d |  |  | SHE; EMC; BBR | 48h |  |

| ID | WBS | Task | Duration | Start | Finish | Predecessors | Complete | Remaining | Total slack | Free slack | Constraint | Resources | Work | Actual work |
| --- | --- | --- | --- | --- | --- | --- | --- | --- | --- | --- | --- | --- | --- | --- |
| 306 | 3.3.4 | **EMC Work** | 21d | 2002-07-05 A | 2002-08-02 |  | 88% | 2.62d | 73.55d |  |  | BBR; EMC | 736h | 630h |
| 307 | 3.5.6.3 | Crosstalk Measurements - FWD East | 4d | 2002-07-05 A | 2002-07-10 A |  | 100% |  |  |  | start no earlier than 2002-07-08 | EMC; FE; BBR | 96h | 96h |
| 308 | 3.5.6.5 | Crosstalk Measurements - BWD West | 3d | 2002-07-11 A | 2002-07-15 A | 307 | 100% |  |  |  |  | EMC; BW; BBR | 72h | 72h |
| 309 | 3.5.6.6 | Crosstalk Measurements - FWD West | 4d | 2002-07-15 A | 2002-07-18 A | 308 | 100% |  |  |  |  | EMC; FW; BBR | 96h | 96h |
| 310 | 3.5.6.7 | Crosstalk Measurements - BWD East | 3d | 2002-07-19 A | 2002-07-23 A | 309 | 100% |  |  |  |  | EMC; BE; BBR | 72h | 72h |
| 311 | 3.3.4.5 | RadFet Work (Night) | 2d | 2002-08-01 | 2002-08-02 |  |  |  | 73.55d |  | start no earlier than 2002-08-01 | EMC; FE; FW; BBR | 64h |  |
| 312 | 3.3.5 | **SVT Mechanical Support** | 31d | 2002-08-12 | 2002-09-24 |  |  |  | 37.55d |  |  |  | 96h |  |
| 313 | 3.3.5.1 | Install FWD SVT Bridge | 1d | 2002-08-12 | 2002-08-12 | 267 |  |  | 67.55d |  |  | HC; CR; PEP; FW; FE; BBR | 48h |  |
| 314 | 3.3.5.2 | Remove FWD SVT Bridge | 1d | 2002-09-24 | 2002-09-24 | 270 |  |  | 37.55d |  |  | HC; CR; FE; FW; PEP; BBR | 48h |  |
| 315 | 3.5.5 | **IFR Barrel Work** | 30d | 2002-07-05 A | 2002-08-15 |  | 57% | 12.92d | 64.55d |  |  | BIFR; BBR; IFRG; IFRH | 3040h | 1730.46h |
| 316 | 3.5.7.2 | Replace HV Distribution Boxes - FWD West | 6d | 2002-07-05 A | 2002-07-12 A |  | 100% |  |  |  | start no earlier than 2002-07-05 | IFRH; FW; BIFR; BBR | 192h | 192h |
| 317 | 3.5.7.3 | IFR Barrel Gas Upgrade - BWD East | 6d | 2002-07-08 | 2002-07-15 |  |  |  | 78.55d | 0d | start no earlier than 2002-07-08 | IFRG; BE; BIFR; BBR | 192h |  |
| 318 | 3.5.7.5 | Replace HV Distribution Boxes - FWD East | 11d | 2002-07-08 A | 2002-07-22 A | 316 | 100% |  |  |  |  | IFRH; FE; BIFR; BBR | 352h | 352h |
| 319 | 3.5.7.11 | IFR Barrel Gas Upgrade - BWD West | 6d | 2002-07-16 | 2002-07-23 | 317 |  |  | 78.55d | 14d | start no earlier than 2002-07-16 | IFRG; BW; BIFR; BBR | 192h |  |
| 320 | 3.5.7.16 | Repair Barrel IFR Chains With Broken FECs - BWD East | 8d | 2002-07-24 | 2002-08-02 |  |  |  | 73.55d |  | start no earlier than 2002-07-24 | IFRF; BIFR; BE; BBR | 256h |  |
| 321 | 3.12.3.1 | Replace HV Distribution Boxes - BWD West | 7d | 2002-07-18 A | 2002-07-26 A | 316, 231 | 100% |  |  |  | start no earlier than 2002-07-29 | IFRH; BW; BIFR; BBR | 224h | 224h |
| 322 | 3.5.7.17 | Repair Barrel IFR Chains With Broken FECs - BWD West | 8d | 2002-08-06 A | 2002-08-15 |  |  | 8d | 64.55d |  | start no earlier than 2002-08-06 | IFRF; BIFR; BW; BBR | 256h |  |
| 323 | 3.12.3.2 | Replace HV Distribution Boxes - BWD East | 13d | 2002-07-10 A | 2002-07-26 A |  | 100% |  |  |  | start no earlier than 2002-08-08 | IFRH; BE; BIFR; BBR | 416h | 416h |
| 324 | 3.3.7 | **IFR Work (Remove Minicrate Racks)** | 19.6d | 2002-07-05 | 2002-08-02 | 208 |  |  | 74.45d |  |  | DIFR; BBR; IFRA; IFRB | 640h |  |
| 325 | 3.3.7.1 | Shut Off AC Power | 1d | 2002-07-05 | 2002-07-08 |  |  |  | 93.05d |  |  | ELECT; DIFR; BBR | 24h |  |
| 326 | 3.3.7.2 | Remove AC Line From Gleason to Minicrate & LV Racks | 1d | 2002-07-05 | 2002-07-08 | 207 |  |  | 93.05d |  |  | ELECT; DIFR; BBR; FE; FW | 40h |  |
| 327 | 3.3.7.3 | Disc LV, Scalar, GMB, AC - LV Racks | 1d | 2002-07-05 | 2002-07-08 |  |  |  | 80.05d | 0d |  | IFRB; DIFR; BBR; FE; FW | 40h |  |
| 328 | 3.3.7.4 | Rem Lyr 18 Minicr, HV Boxes, Gas - West | 1d | 2002-07-05 | 2002-07-08 |  |  |  | 81.05d | 0d |  | IFRA; DIFR; BBR; FW | 32h |  |
| 329 | 3.3.7.5 | Rem Lyr 18 Minicr, HV Boxes, Gas - East | 2d | 2002-07-08 | 2002-07-10 | 327 |  |  | 80.05d | 0d |  | IFRB; DIFR; BBR; FE | 64h |  |
| 330 | 3.3.7.6 | Disc & Dress to Minicr Rack Sclr Cables from Minicr Rack to DMUX Brds in LV Rack | 1d | 2002-07-08 | 2002-07-09 | 328 |  |  | 81.05d | 0d |  | IFRA; DIFR; BBR; FE; FW | 40h |  |
| 331 | 3.3.7.7 | Disc & Rem DAQ Cabling Bewteen Layer 18 Minicr and FEE Crates | 1d | 2002-07-10 | 2002-07-11 | 329 |  |  | 80.05d | 0d |  | IFRB; DIFR; BBR; FE; FW | 40h |  |
| 332 | 3.3.7.8 | Disc Minicr End of RPC-Minicr Cables/Remove Raceways - Lower East & West | 1d | 2002-07-11 | 2002-07-12 | 331 |  |  | 80.05d | 0d |  | IFRB; DIFR; BBR; FE; FW | 40h |  |
| 333 | 3.3.7.9 | Rem Raceways & Misc Cables Connecting Minicr Racks to Detector | 1d | 2002-07-09 | 2002-07-10 | 330 |  |  | 81.05d | 0d |  | IFRA; DIFR; FE; FW; BBR | 40h |  |
| 334 | 3.3.7.10 | Disc Minicr End of RPC-Minicr Cables/Remove Raceways - Upper East & West | 3d | 2002-07-10 | 2002-07-15 | 333 |  |  | 81.05d | 0d |  | DIFR; FE; FW; BBR; IFRA | 120h |  |
| 335 | 3.3.7.11 | Disc & Rem LV Wiring Running from Layer 18 to Racks | 1d | 2002-07-15 | 2002-07-16 | 334 |  |  | 81.05d | 0d |  | IFRA; DIFR; FE; FW; BBR | 40h |  |
| 336 | 3.3.7.12 | Dress All Lines back to Gleason | 1d | 2002-07-12 | 2002-07-15 | 332 |  |  | 80.05d | 0d |  | IFRB; DIFR; FE; FW; BBR | 40h |  |
| 337 | 3.3.7.13 | Remove Minicr Racks - West | 1d | 2002-07-31 | 2002-08-01 | 336, 404 |  |  | 74.45d | 0d |  | HC; CR; FW; DIFR; BBR | 40h |  |
| 338 | 3.3.7.14 | Remove Minicr Racks - East | 1d | 2002-08-01 | 2002-08-02 | 336, 337 |  |  | 74.45d |  |  | HC; CR; FE; DIFR; BBR | 40h |  |

| ID | WBS | Task | Type | Duration | Start | Finish | Predecessors | Complete | Remaining | Total slack | Free slack | Resources | Work | Actual work |
| --- | --- | --- | --- | --- | --- | --- | --- | --- | --- | --- | --- | --- | --- | --- |
| 339 | 3.3.8 | **IFR Work (Rebuild Minicrate Racks)** |  | 14.63d | 2002-07-18 A | 2002-08-07 |  | 19% | 11.88d | 70.92d |  | IFRB; IFRA; DIFR; BBR | 978.4h | 184.08h |
| 340 | 3.3.8.1 | West Minicr Racks - Relabel, Reterminate, Modify and Reinstall RPC to Minicr Cables |  | 2d | 2002-07-25 A | 2002-07-26 A | 363 | 100% |  |  |  | IFRB; DIFR; BBR | 48h | 48h |
| 341 | 3.3.8.2 | West Minicr Racks - Relocate LV Supplies into Rack |  | 0.5d | 2002-07-29 | 2002-07-29 | 340 |  |  | 73.92d | 0d | IFRB; DIFR; BBR | 12h |  |
| 342 | 3.3.8.3 | West Minicr Racks - Relocate GMB/MUX Crate into Rack |  | 0.13d | 2002-07-29 | 2002-07-29 | 341 |  |  | 73.92d | 0d | IFRB; DIFR; BBR | 3.12h |  |
| 343 | 3.3.8.4 | West Minicr Racks - Install LV and DAQ Cables |  | 2d | 2002-07-29 | 2002-07-31 | 342 |  |  | 73.92d | 0d | IFRB; DIFR; BBR | 48h |  |
| 344 | 3.3.8.5 | West Minicr Racks - Test and Debug Minicrates |  | 2d | 2002-07-31 | 2002-08-02 | 343 |  |  | 73.92d | 0d | IFRB; DIFR; BBR | 48h |  |
| 345 | 3.3.8.6 | West Minicrate Racks Ready for Installation | milestone | 0d | 2002-08-02 | 2002-08-02 | 344 |  |  | 73.92d |  | IFRB; DIFR; BBR; IFRA |  |  |
| 346 | 3.3.8.7 | East& West Minicr Racks - Mod Layer 18 Minicr and Install in New Rack Locations |  | 2d | 2002-07-18 A | 2002-07-19 A | 361 | 100% |  |  |  | IFRA; DIFR; BBR | 48h | 48h |
| 347 | 3.3.8.8 | East Minicr Racks - Relabel, Reterminate, Modify and Reinstall RPC to Minicr Cables |  | 8d | 2002-07-22 | 2002-07-31 | 346 |  |  | 70.92d | 0d | IFRA; DIFR; BBR | 192h |  |
| 348 | 3.3.8.9 | East Minicr Racks - Relocate LV Supplies into Rack |  | 0.5d | 2002-08-01 | 2002-08-01 | 347 |  |  | 70.92d | 0d | IFRA; DIFR; BBR | 12h |  |
| 349 | 3.3.8.10 | East Minicr Racks - Relocate GMB/MUX Crate into Rack |  | 0.13d | 2002-08-01 | 2002-08-01 | 348 |  |  | 70.92d | 0d | IFRA; DIFR; BBR | 3.12h |  |
| 350 | 3.3.8.11 | East Minicr Racks - Install LV and DAQ Cables |  | 2d | 2002-08-01 | 2002-08-05 | 349 |  |  | 70.92d | 0d | IFRA; DIFR; BBR | 48h |  |
| 351 | 3.3.8.12 | East Minicr Racks - Test and Debug Minicrates |  | 2d | 2002-08-05 | 2002-08-07 | 350 |  |  | 70.92d | 0d | IFRA; DIFR; BBR | 48h |  |
| 352 | 3.3.8.13 | East Minicrate Racks Ready for Installation | milestone | 0d | 2002-08-07 | 2002-08-07 | 351 |  |  | 70.92d |  | IFRA; DIFR; BBR; IFRB |  |  |
| 353 | 3.3.9 | **IFR FWD End Door Upgrade (Prep for RPC Removal)** |  | 55d | 2002-07-17 | 2002-10-02 |  |  |  | 31.55d |  | DIFR; BBR; IFRA; IFRB | 2296h |  |
| 354 | 3.3.9.1 | Disc RPC End of RPC-Minicr Cables -Upr East |  | 1d | 2002-07-17 | 2002-07-17 | 335, 239 |  |  | 80.55d | 0d | IFRA; DIFR; FE; BBR | 32h |  |
| 355 | 3.3.9.2 | Remove Gas Lines at RPC End - Upr |  | 3d | 2002-07-18 | 2002-07-22 | 354 |  |  | 80.55d | 0d | IFRA; FE; FW; DIFR; BBR | 120h |  |
| 356 | 3.3.9.3 | Disc RPC End of RPC-Minicr Cables - Upr West |  | 2d | 2002-07-26 | 2002-07-29 | 336, 258 |  |  | 68.55d | 0d | IFRB; FW; DIFR; BBR | 64h |  |
| 357 | 3.3.9.4 | Cut & Rem HV Lines at RPC End - Upr |  | 1d | 2002-07-23 | 2002-07-23 | 355 |  |  | 80.55d | 0d | IFRA; FE; FW; DIFR; BBR | 40h |  |
| 358 | 3.5.11.27 | Remove Gas Lines at RPC End (Middle & Lower) |  | 1d | 2002-07-30 | 2002-07-30 | 356 |  |  | 68.55d | 0d | IFRB; FE; FW; DIFR; BBR | 40h |  |
| 359 | 3.5.11.28 | Cut & Rem HV Lines at RPC End (Middle & Lower) |  | 1d | 2002-07-31 | 2002-07-31 | 358 |  |  | 68.55d | 0d | IFRB; FE; FW; DIFR; BBR | 40h |  |
| 360 | 3.5.11.29 | Cut & Rem RPC-Minicr Cables(Vert Strips) at RPC End/Rem Bot Raceway (Mid & Lwr) |  | 1d | 2002-08-01 | 2002-08-01 | 359 |  |  | 68.55d | 0d | IFRB; FE; FW; DIFR; BBR | 40h |  |
| 361 | 3.5.11.30 | Cut & Rem RPC-Minicr Cables(Vert Strips) at RPC End - Upr |  | 1d | 2002-07-24 | 2002-07-24 | 357 |  |  | 80.55d |  | IFRA; FE; FW; DIFR; BBR | 40h |  |
| 362 | 3.5.11.31 | Remove Temperature Probes |  | 1d | 2002-08-02 | 2002-08-02 | 360 |  |  | 68.55d | 40d | IFRB; FE; FW; DIFR; BBR | 40h |  |
| 363 | 3.5.11.41 | Remove Midplane Raceways & Cables |  | 2d | 2002-10-01 | 2002-10-02 | 362, 267, 271 |  |  | 28.55d | 0d | IFRB; FE; FW; DIFR; BBR | 80h |  |

| ID | WBS | Task | Duration | Start | Finish | Predecessors | Complete | Remaining | Total slack | Free slack | Constraint | Resources | Work | Actual work |
| --- | --- | --- | --- | --- | --- | --- | --- | --- | --- | --- | --- | --- | --- | --- |
| 364 | 3.3.10 | **DIRC Work** | 45.1d | 2002-07-24 A | 2002-09-26 |  | 24% | 34.1d | 36.45d |  |  | DIRC; BBR | 844.8h | 224h |
| 365 | 3.3.10.1 | Install DIRC Access Platform | 1d | 2002-09-06 A | 2002-09-06 A | 268 | 100% |  |  |  |  | HC; CR; DIRC; BB; PEP; BBR | 48h | 48h |
| 366 | 3.3.10.2 | Remove All DFBs (12x14) | 3d | 2002-07-24 | 2002-07-26 |  |  |  | 78.55d |  | start no earlier than 2002-07-24 | DIRC; BB; BBR | 72h |  |
| 367 | 3.3.10.3 | Remove DIRC Access Platform | 0.1d | 2002-09-26 | 2002-09-26 | 276 |  |  | 36.45d |  |  | HC; CR; DIRC; BBR | 3.2h |  |
| 369 | 3.4 | **Remove Backward Raft** | 29.8d | 2002-07-05 | 2002-08-15 |  |  |  | 10.4d |  |  | PEP; BBR; HC | 1732.4h |  |
| 370 | 3.4.1 | **Disconnect Backward PEPII Services** | 4.5d | 2002-07-05 | 2002-07-11 |  |  |  | 10.4d |  |  | PEP | 116h |  |
| 371 | 3.4.1.1 | Disconnect TC Cables | 0.5d | 2002-07-05 | 2002-07-05 | 206 |  |  | 94.05d |  |  | PEP; S.Ecklund | 8h |  |
| 372 | 3.4.1.2 | Disconnect Power Cables | 2d | 2002-07-05 | 2002-07-08 | 206 |  |  | 7.85d | 0d |  | PEP; PC | 32h |  |
| 373 | 3.4.1.3 | Secure Cables to Raft | 0.5d | 2002-07-09 | 2002-07-09 | 372 |  |  | 86.35d | 0d |  | PEP; PC | 8h |  |
| 374 | 3.4.1.4 | Drain, Disconnect & Plug Water Cooling Systems | 2d | 2002-07-09 | 2002-07-11 | 373 |  |  | 86.35d | 2.05d |  | PEP; MFD | 32h |  |
| 375 | 3.4.2 | **Disconnect Backward SVT Services** | 4.35d | 2002-07-05 | 2002-07-11 |  |  |  | 84.3d |  |  | PEP | 104.4h |  |
| 376 | 3.4.2.1 | Drain, Flush and Disconnect Cooling System | 0.25d | 2002-07-05 | 2002-07-05 | 206 |  |  | 84.3d | 0d |  | PEP; SVT Tech | 4h |  |
| 377 | 3.4.2.2 | Disconnect Dry Air Hoses | 0.1d | 2002-07-05 | 2002-07-05 | 376 |  |  | 84.3d | 0d |  | PEP; SVT Tech | 1.6h |  |
| 378 | 3.4.2.3 | Disconnect White Cables at Front of Raft | 0.5d | 2002-07-05 | 2002-07-05 | 377 |  |  | 84.3d | 0d |  | PEP; SVT Tech | 8h |  |
| 379 | 3.4.2.4 | Disconnect White Cables at MUX Racks | 3d | 2002-07-05 | 2002-07-10 | 378 |  |  | 86.5d | 0d |  | PEP; SVT Tech | 48h |  |
| 380 | 3.4.2.5 | Secure Cables at Raft | 0.5d | 2002-07-10 | 2002-07-11 | 379 |  |  | 86.5d | 2.2d |  | PEP; SVT Tech | 8h |  |
| 381 | 3.4.3 | **Disconnect Backward DC Services** | 5.7d | 2002-07-05 | 2002-07-15 |  |  |  | 84.3d |  |  | PEP | 136.8h |  |
| 382 | 3.4.3.1 | Drain and Flush Cooling System | 1d | 2002-07-05 | 2002-07-08 | 378 |  |  | 84.3d | 0d |  | PEP; DC Tech | 16h |  |
| 383 | 3.4.3.2 | Disconnect Chamber Exhaust, Install Bubbler | 0.1d | 2002-07-08 | 2002-07-08 | 382 |  |  | 84.3d | 0d |  | PEP; DC Tech | 1.6h |  |
| 384 | 3.4.3.3 | Disconnect High Voltage | 0.1d | 2002-07-08 | 2002-07-09 | 383 |  |  | 84.3d | 0d |  | PEP; DC Tech | 1.6h |  |
| 385 | 3.4.3.4 | Disconnect Low Voltage | 0.1d | 2002-07-09 | 2002-07-09 | 384 |  |  | 84.3d | 0d |  | PEP; DC Tech | 1.6h |  |
| 386 | 3.4.3.5 | Disconnect Gas Lines, Install Plugs | 0.25d | 2002-07-09 | 2002-07-09 | 385 |  |  | 84.3d | 0d |  | PEP; DC Tech | 4h |  |
| 387 | 3.4.3.6 | Disconnect Water Lines, Install Plugs | 0.25d | 2002-07-09 | 2002-07-09 | 386 |  |  | 84.3d | 0d |  | PEP; DC Tech | 4h |  |
| 388 | 3.4.3.7 | Disconnect Fibers | 0.1d | 2002-07-09 | 2002-07-09 | 387 |  |  | 84.3d | 0d |  | PEP; DC Tech | 1.6h |  |
| 389 | 3.4.3.8 | Disconnect Environmental Cables | 0.1d | 2002-07-09 | 2002-07-09 | 388 |  |  | 84.3d | 0d |  | PEP; DC Tech | 1.6h |  |
| 390 | 3.4.3.9 | Secure Fibers, Cables & Hoses to Raft | 0.25d | 2002-07-09 | 2002-07-10 | 389 |  |  | 84.3d | 0d |  | PEP; DC Tech | 4h |  |
| 391 | 3.4.3.10 | Remove Extender Lines | 0.1d | 2002-07-10 | 2002-07-10 | 390 |  |  | 84.3d | 0d |  | PEP; DC Tech | 1.6h |  |
| 392 | 3.4.3.11 | Disconnect Gas Lines at Back of Raft, Secure to Raft | 0.25d | 2002-07-10 | 2002-07-10 | 391 |  |  | 84.3d | 0d |  | PEP; DC Tech | 4h |  |
| 393 | 3.4.3.12 | Disconnect Water Lines at Back of Raft, Secure to Raft | 0.1d | 2002-07-10 | 2002-07-10 | 392 |  |  | 84.3d | 0d |  | PEP; DC Tech | 1.6h |  |
| 394 | 3.4.3.13 | Cut Cables to Electronics House, Secure to Raft | 3d | 2002-07-10 | 2002-07-15 | 393 |  |  | 84.3d | 0d |  | PEP; DC Tech | 48h |  |

| ID | WBS | Task | Duration | Start | Finish | Predecessors | Total slack | Free slack | Constraint | Resources | Work |
| --- | --- | --- | --- | --- | --- | --- | --- | --- | --- | --- | --- |
| 395 | 3.4.4 | **Disconnect Backward Vacuum** | 2d | 2002-07-10 | 2002-07-12 |  | 85.65d |  |  | PEP | 56.8h |
| 396 | 3.4.4.1 | Vent vacuum system | 1d | 2002-07-10 | 2002-07-11 | 391 | 85.65d | 0d |  | PEP; MFD | 16h |
| 397 | 3.4.4.2 | Shut down vertex chamber cooling system | 0.1d | 2002-07-10 | 2002-07-10 | 392 | 85.8d | 0d |  | PEP; SJM | 0.8h |
| 398 | 3.6.4.1 | Remove Flex Hoses as Required to Access Bellows | 0.5d | 2002-07-10 | 2002-07-11 | 397 | 85.8d | 0.15d |  | PEP; MFD | 8h |
| 399 | 3.6.4.2 | Remove Backward Q1/Q2 Bellows | 1d | 2002-07-11 | 2002-07-12 | 398, 396 | 85.65d | 1.35d |  | PEP; MFD | 16h |
| 400 | 3.4.5 | **Disconnect ST and Raft, Remove Backward Raft** | 23.25d | 2002-07-15 | 2002-08-15 |  | 64.75d |  |  | PEP; HC | 603.2h |
| 401 | 3.4.5.1 | Remove Northeast Short Stair | 1d | 2002-07-26 | 2002-07-26 | 246 | 74.45d | 0d |  | HC; CR; PEP; BBR; BE | 40h |
| 402 | 3.4.5.2 | Install Shielding Block - BWD West | 0.1d | 2002-07-29 | 2002-07-29 | 401 | 74.45d | 0d |  | HC; CR; BW; PEP; BBR | 4h |
| 403 | 3.4.5.3 | Remove Northwest Cable Tray Cover on Floor | 1d | 2002-07-29 | 2002-07-30 | 402 | 74.45d | 0d |  | HC; CR; BE; BBR; PEP | 40h |
| 404 | 3.4.5.4 | Remove Northwest Stairway | 1d | 2002-07-30 | 2002-07-31 | 403 | 74.45d | 0d |  | HC; CR; BW; PEP; BBR | 40h |
| 405 | 3.4.5.5 | Fit Lifting Brackets to Raft | 0.1d | 2002-07-15 | 2002-07-15 | 399, 394, 380, 374 | 84.3d | 0d |  | PEP; MFD | 1.6h |
| 406 | 3.4.5.6 | Setup Temporary Backward ST supports | 0.5d | 2002-07-15 | 2002-07-16 | 405 | 84.3d | 0d |  | PEP; MFD | 8h |
| 407 | 3.4.5.7 | Transfer ST Load to Temporary Support | 0.1d | 2002-07-16 | 2002-07-16 | 406 | 84.3d | 0d |  | PEP; MFD | 1.6h |
| 408 | 3.4.5.8 | Disconnect Yoke | 0.25d | 2002-07-16 | 2002-07-16 | 407 | 84.3d | 0d |  | PEP; MFD | 4h |
| 409 | 3.4.5.9 | Remove Fasteners Securing Raft | 0.25d | 2002-07-16 | 2002-07-16 | 408 | 84.3d | 19.55d |  | PEP; MFD | 4h |
| 410 | 3.4.5.10 | Crane Out BWD Raft (Incl Rollback & Transfer Stage) | 2d | 2002-08-13 | 2002-08-15 | 409, 405, 428, 263 | 64.75d | 0d |  | HC; CR; PEP; BB; BBR | 80h |
| 411 | 3.4.5.11 | Transport Raft to Storage Area | 0.5d | 2002-08-15 | 2002-08-15 | 410 | 64.75d |  |  | PEP; Riggers | 8h |
| 413 | 3.5 | **Remove Beamlines in Tunnel to -15m from IP** | 8.75d | 2002-07-05 | 2002-07-17 |  | 83.8d |  |  | PEP | 352h |
| 414 | 3.5.1 | Remove Luminosity Monitor Lead Shielding & Counters | 1d | 2002-07-05 | 2002-07-05 | 206 | 93.3d | 0d |  | PEP; C. Field; MFD | 24h |
| 415 | 3.5.2 | Remove Lumi Monitor Cables and Electronics | 0.25d | 2002-07-08 | 2002-07-08 | 414 | 93.3d |  |  | PEP; C. Field; MFD | 6h |
| 416 | 3.5.3 | Remove Lead Shielding at HER LP Chamber | 0.5d | 2002-07-05 | 2002-07-05 | 206 | 83.8d | 0.5d |  | PEP; MFD | 8h |
| 417 | 3.5.4 | Remove Lead Shielding at Collimator | 1d | 2002-07-08 | 2002-07-08 | 416 | 89.55d | 0d | start no earlier than 2002-07-07 | PEP; MFD | 16h |
| 418 | 3.5.5 | Remove Lead Shielding at Frangible Link | 1d | 2002-07-09 | 2002-07-09 | 417 | 89.55d | 0d |  | PEP; MFD | 16h |
| 419 | 3.5.6 | Remove Backward Frangible Link | 2d | 2002-07-10 | 2002-07-11 | 418 | 89.55d |  |  | PEP; MFD | 32h |
| 420 | 3.5.7 | Disconnect Power, Water, TC & Klixons to LER & HER Beamlines | 2d | 2002-07-08 | 2002-07-09 | 416 | 83.3d | 0d | start no earlier than 2002-07-07 | PEP; MFD; PC | 48h |
| 421 | 3.5.8 | Remove LER & HER Beamlines, Valve, Pumps | 3d | 2002-07-10 | 2002-07-12 | 420 | 83.3d | 0d |  | PEP; MFD | 48h |
| 422 | 3.5.9 | Disconnect Water, Controls & TC to Collimator | 0.5d | 2002-07-09 | 2002-07-09 | 417 | 91.05d | 0d |  | PEP; MFD | 8h |
| 423 | 3.5.10 | Disconnect Power, Water & TC to BV1 Raft | 1d | 2002-07-09 | 2002-07-10 | 422 | 91.05d |  |  | PEP; MFD; PC | 24h |
| 424 | 3.5.11 | Remove Collimator | 1d | 2002-07-15 | 2002-07-15 | 421 | 83.3d | 0d |  | PEP; MFD | 16h |
| 425 | 3.5.12 | Remove Lumi Monitor Chamber | 0.25d | 2002-07-16 | 2002-07-16 | 424 | 83.3d | 0d |  | PEP; MFD | 4h |
| 426 | 3.5.13 | Remove Collimator Support Table | 0.25d | 2002-07-16 | 2002-07-16 | 425 | 83.3d | 0d |  | PEP; MFD | 4h |
| 427 | 3.5.14 | Remove Corrector and Support Table | 0.25d | 2002-07-16 | 2002-07-16 | 426 | 83.3d | 0d |  | PEP; MFD | 4h |
| 428 | 3.5.15 | Move BV1 Raft into Alcove | 1d | 2002-07-16 | 2002-07-17 | 427 | 83.3d | 18.55d |  | PEP; Riggers; MFD | 24h |

Notes:
- 397: See procedure

| ID | WBS | Task | Duration | Start | Finish | Predecessors | Total slack | Free slack | Resources | Work |
| --- | --- | --- | --- | --- | --- | --- | --- | --- | --- | --- |
| 430 | 3.6 | **Remove Forward Raft** | 15.3d | 2002-07-09 | 2002-07-30 |  | 10.4d |  | PEP; BBR; HC | 738.8h |
| 431 | 3.6.1 | **Disconnect Forward SVT Services** | 1d | 2002-07-24 | 2002-07-24 |  | 3.9d |  | PEP | 32h |
| 432 | 3.6.1.1 | Disconnect White Cables, Tie back Beyond Forward Calorimeter | 1d | 2002-07-24 | 2002-07-24 | 265 | 80.55d |  | PEP; SVT Tech | 16h |
| 433 | 3.6.1.2 | Drain, Flush and Disconnect Cooling System | 0.1d | 2002-07-24 | 2002-07-24 | 265 | 3.9d | 0d | PEP; SVT Tech | 1.6h |
| 434 | 3.6.1.3 | Disconnect Dry Air Hoses | 0.1d | 2002-07-24 | 2002-07-24 | 433 | 3.9d | 0d | PEP; SVT Tech | 1.6h |
| 435 | 3.6.1.4 | Secure Hoses to Raft | 0.1d | 2002-07-24 | 2002-07-24 | 434 | 3.9d | 0d | PEP; SVT Tech | 1.6h |
| 436 | 3.6.1.5 | Disconnect Position Sensor Cables | 0.1d | 2002-07-24 | 2002-07-24 | 435 | 3.9d | 0d | PEP; C.Cheng | 1.6h |
| 437 | 3.6.1.6 | Disconnect EMC Monitoring Board Cables | 0.1d | 2002-07-24 | 2002-07-24 | 436 | 3.9d | 0d | PEP; Jong Yi | 1.6h |
| 438 | 3.6.2 | **Disconnect Forward PEPII Services** | 12.5d | 2002-07-09 | 2002-07-25 |  | 3.9d |  | PEP | 196h |
| 439 | 3.6.2.1 | Disconnect TC Cables | 0.5d | 2002-07-09 | 2002-07-09 | 372 | 10.4d | 0d | PEP; S.Ecklund | 8h |
| 440 | 3.6.2.2 | Disconnect Power Cables | 2d | 2002-07-09 | 2002-07-11 | 439 | 10.4d | 0d | PEP; PC | 32h |
| 441 | 3.6.2.3 | Secure Cables to Raft | 0.5d | 2002-07-11 | 2002-07-11 | 440 | 10.4d | 0d | PEP; PC | 8h |
| 442 | 3.6.2.4 | Drain, Flush & Plug Water Cooling System | 2d | 2002-07-12 | 2002-07-15 | 441 | 10.4d | 6.5d | PEP; MFD | 32h |
| 443 | 3.6.2.5 | Disconnect Pipes, Manifolds & Cables at Front of Raft | 1d | 2002-07-24 | 2002-07-25 | 442, 437 | 3.9d | 0d | PEP; MFD | 16h |
| 444 | 3.6.3 | **Disconnect Forward Vacuum** | 2d | 2002-07-25 | 2002-07-29 |  | 3.9d |  | PEP | 64h |
| 445 | 3.6.3.1 | Remove Forward Q1/Q2 Bellows | 1d | 2002-07-25 | 2002-07-26 | 443 | 3.9d | 0d | PEP; MFD | 16h |
| 446 | 3.6.3.2 | Remove Forward Frangible Link | 2d | 2002-07-25 | 2002-07-29 | 443 | 78.05d |  | PEP; MFD | 32h |
| 447 | 3.6.4 | **Transfer ST Load and Remove Raft** | 1.8d | 2002-07-26 | 2002-07-30 |  | 3.9d |  | PEP; BBR; HC | 91.6h |
| 448 | 3.6.4.1 | Fit Lifting Brackets to Raft | 0.1d | 2002-07-26 | 2002-07-26 | 445 | 3.9d | 0d | PEP; HC; FB; BBR | 3.2h |
| 449 | 3.6.4.2 | Install Extension Table for FC Extraction System | 0.25d | 2002-07-26 | 2002-07-26 | 448 | 3.9d | 0d | PEP; HC; CR; FB; BBR | 10h |
| 450 | 3.6.4.3 | Install ST Forward Temporary Support | 0.25d | 2002-07-26 | 2002-07-29 | 449, 192 | 3.9d | 0d | PEP; HC; CR; FB; BBR | 10h |
| 451 | 3.6.4.4 | Transfer ST Load to Temp Support | 0.1d | 2002-07-29 | 2002-07-29 | 450 | 3.9d | 0d | PEP; MFD | 1.6h |
| 452 | 3.6.4.5 | Disconnect Yoke | 0.1d | 2002-07-29 | 2002-07-29 | 451 | 3.9d | 0d | PEP; MFD | 1.6h |
| 453 | 3.6.4.6 | Remove Fasteners Securing Raft | 0.25d | 2002-07-29 | 2002-07-29 | 452 | 3.9d | 0d | PEP; MFD | 4h |
| 454 | 3.6.4.7 | Crane Out Raft | 0.25d | 2002-07-29 | 2002-07-29 | 453, 450 | 3.9d | 0d | PEP; HC; CR; FB; BBR | 10h |
| 455 | 3.6.4.8 | Transport Forward Raft to Heavy Fab. | 0.5d | 2002-07-29 | 2002-07-30 | 454 | 60.44d | 0d | PEP; Riggers | 8h |
| 457 | 3.7 | Replace Q2 Chamber on Forward Raft | 16.81d | 2002-07-30 | 2002-08-22 | 455 | 60.44d |  | PEP | 134.48h |

| ID | WBS | Task | Type | Duration | Start | Finish | Predecessors | Total slack | Free slack | Constraint | Resources | Work |
| --- | --- | --- | --- | --- | --- | --- | --- | --- | --- | --- | --- | --- |
| 459 | 3.8 | **Install supports and remove Support Tube** |  | 2.8d | 2002-07-29 | 2002-08-01 |  | 3.9d |  |  | PEP; BBR; HC | 179.2h |
| 460 | 3.8.1 | Attach Forward Crane Brackets to ST |  | 0.25d | 2002-07-29 | 2002-07-30 | 454 | 77.5d |  |  | PEP; HC; FB; BBR | 8h |
| 461 | 3.8.2 | Install Backward Roller Frames |  | 0.45d | 2002-07-29 | 2002-07-30 | 454 | 3.9d | 0d |  | PEP; HC; CR; BB; BBR | 18h |
| 462 | 3.8.3 | Install Backward Insertion Beam |  | 0.5d | 2002-07-30 | 2002-07-30 | 461 | 3.9d | 0d |  | PEP; HC; CR; BB; BBR | 20h |
| 463 | 3.8.4 | Secure SVT Cables to Insertion Beam |  | 0.25d | 2002-07-30 | 2002-07-30 | 462 | 3.9d | 0d |  | PEP; SVT Tech | 4h |
| 464 | 3.8.5 | Pickup Backward ST Using Insertion Beam |  | 0.25d | 2002-07-31 | 2002-07-31 | 463 | 3.9d | 0d |  | PEP; HC; BB; BBR | 8h |
| 465 | 3.8.6 | Pickup Forward ST Using Crane |  | 0.1d | 2002-07-31 | 2002-07-31 | 464 | 3.9d | 0d |  | PEP; HC; CR; FB; BBR | 4h |
| 466 | 3.8.7 | Rollout ST |  | 1d | 2002-07-31 | 2002-08-01 | 465 | 3.9d | 0d |  | PEP; HC; CR; FB; BBR | 40h |
| 467 | 3.8.8 | Pickup ST with Spreader Bar, Setdown on Transport Frame |  | 0.25d | 2002-08-01 | 2002-08-01 | 466 | 3.9d | 0d |  | PEP; HC; CR; FB; BBR | 10h |
| 469 | 3.9 | **Prepare to close Forward Doors** |  | 1.5d | 2002-08-01 | 2002-08-05 |  | 73.45d |  |  | PEP; BBR; HC | 96h |
| 470 | 3.9.1 | Remove Temp Support |  | 0.5d | 2002-08-01 | 2002-08-02 | 467 | 73.45d | 0d |  | PEP; HC; CR; FB; BBR | 20h |
| 471 | 3.9.2 | Remove Extension Table |  | 0.5d | 2002-08-02 | 2002-08-02 | 470 | 73.45d | 0d |  | PEP; HC; CR; FB; BBR | 20h |
| 472 | 3.9.3 | Remove PEP Support Pedastal top plate |  | 0.5d | 2002-08-02 | 2002-08-05 | 471 | 73.45d |  |  | HC; CR; PEP; FB; BBR | 20h |
| 475 | 3.10 | **BABAR WORK, PHASE 2 (ST Removed)** |  | 67.05d | 2002-08-09 | 2002-11-13 |  | 2.5d |  |  | PEP; BBR; HC | 12310.8h |
| 476 | 3.10.1 | **CRYO Work** |  | 1d | 2002-09-11 | 2002-09-11 |  | 46.55d |  |  |  | 24h |
| 477 | 3.10.1.1 | Install Magnet Contactors |  | 1d | 2002-09-11 | 2002-09-11 |  | 46.55d |  | start no earlier than 2002-09-11 | CRYO; BBR; BW | 24h |
| 478 | 3.12.1 | **IFR End Door Upgrade** |  | 56.8d | 2002-08-23 | 2002-11-12 |  | 2.5d |  |  | DIFR; BBR; IFRA; IFRB; HC | 5910.8h |
| 479 | 3.12.1.13 | Transport New Lwr West Chambers to IR-2 |  | 1d | 2002-08-23 | 2002-08-23 | 623 | 2.5d | 0d |  | HC; DIFR; BBR | 24h |
| 480 | 3.12.1.14 | Install Brass Absorber - Lwr West |  | 2d | 2002-08-26 | 2002-08-27 | 479, 54, 67 | 2.5d | 0d |  | HC; CR; FW; DIFR; BBR | 80h |
| 481 | 3.12.1.15 | Install Work Platform - Lwr West |  | 1d | 2002-08-28 | 2002-08-28 | 480, 131 | 2.5d | 0d |  | HC; CR; FW; DIFR; BBR | 40h |
| 482 | 3.12.1.16 | Rem & Install Chambers - Lwr West |  | 2d | 2002-08-29 | 2002-08-30 | 481, 118 | 2.5d | 0d |  | HC; CR; FW; DIFR; BBR | 80h |
| 483 | 3.12.1.17 | Remove Work Platform - Lwr West |  | 1d | 2002-09-03 | 2002-09-03 | 482 | 2.5d | 0d |  | HC; CR; FW; DIFR; BBR | 40h |
| 484 | 3.12.1.18 | Connect RPC Gas - Lwr West |  | 1d | 2002-09-03 | 2002-09-03 | 482 | 51.55d | 0d |  | IFRA; FW; DIFR; BBR | 32h |
| 485 | 3.12.1.19 | Quick Test of Installed RPCs - Lwr West |  | 1d | 2002-09-04 | 2002-09-04 | 484 | 51.55d |  |  | IFRA; FW; DIFR; BBR | 32h |
| 486 | 3.12.1.20 | Transport Old Lwr West Chambers to CEH |  | 1d | 2002-09-04 | 2002-09-04 | 483 | 2.5d | 0d |  | HC; DIFR; BBR | 24h |
| 487 | 3.12.1.21 | Transport New Lwr East Chambers to IR-2 |  | 1d | 2002-09-05 | 2002-09-05 | 486 | 2.5d | 0d |  | HC; DIFR; BBR | 24h |
| 488 | 3.12.1.22 | Install Brass Absorber - Lwr East |  | 2d | 2002-09-06 | 2002-09-09 | 487 | 2.5d | 0d |  | HC; CR; FE; DIFR; BBR | 80h |
| 489 | 3.12.1.23 | Install Work Platform - Lwr East |  | 1d | 2002-09-10 | 2002-09-10 | 488 | 2.5d | 0d |  | HC; CR; FE; DIFR; BBR | 40h |
| 490 | 3.12.1.24 | Rem & Install Chambers - Lwr East |  | 2d | 2002-09-11 | 2002-09-12 | 489 | 2.5d | 0d |  | HC; CR; FE; DIFR; BBR | 80h |
| 491 | 3.12.1.25 | Install SE Stair - Lower |  | 0.1d | 2002-09-13 | 2002-09-13 | 490 | 2.5d | 0d |  | HC; CR; FE; DIFR; BBR | 4h |
| 492 | 3.12.1.26 | Remove Work Platform - Lwr East |  | 1d | 2002-09-13 | 2002-09-16 | 491 | 2.5d | 0d |  | HC; CR; FE; DIFR; BBR | 40h |
| 493 | 3.12.1.27 | Connect RPC Gas - Lwr East |  | 1d | 2002-09-13 | 2002-09-13 | 490 | 10.7d | 0d |  | IFRA; FE; DIFR; BBR | 32h |
| 494 | 3.12.1.28 | Quick Test of Installed RPCs - Lwr East |  | 1d | 2002-09-16 | 2002-09-16 | 493 | 10.7d | 5.2d |  | IFRA; FE; DIFR; BBR | 32h |
| 495 | 3.12.1.29 | Transport Old Lwr East Chambers to CEH |  | 1d | 2002-09-16 | 2002-09-17 | 492 | 2.5d | 0d |  | HC; DIFR; BBR | 24h |
| 496 | 3.12.1.30 | Install SW Stair - Middle |  | 0.1d | 2002-09-17 | 2002-09-17 | 495 | 2.5d | 0d |  | HC; CR; FW; DIFR; BBR | 4h |
| 497 | 3.12.1.31 | Install Work Platform - Mid West |  | 1d | 2002-09-17 | 2002-09-18 | 496 | 2.5d | 0d |  | HC; CR; FW; DIFR; BBR | 40h |
| 498 | 3.12.1.32 | Transport New Mid West Chambers to IR-2 |  | 1d | 2002-09-18 | 2002-09-19 | 497 | 2.5d | 0d |  | HC; DIFR; BBR | 24h |
| 499 | 3.12.1.33 | Install Brass Absorber - Mid West |  | 1d | 2002-09-19 | 2002-09-20 | 498 | 2.5d | 0d |  | HC; CR; FW; DIFR; BBR | 40h |
| 500 | 3.10.2.22 | Retrieve Lwr East & Lwr West Flux Bars From Shop |  | 1d | 2002-09-20 | 2002-09-23 | 499 | 39.35d |  |  | HC; CR; DIFR; BBR | 32h |
| 501 | 3.12.1.34 | Rem & Install Chambers - Mid west |  | 2d | 2002-09-20 | 2002-09-24 | 499 | 2.5d | 0d |  | HC; CR; FW; DIFR; BBR | 80h |
| 502 | 3.12.1.35 | Connect RPC Gas - Mid West |  | 1d | 2002-09-24 | 2002-09-25 | 494, 501 | 5.5d | 0d |  | IFRA; FW; DIFR; BBR | 32h |
| 503 | 3.12.1.36 | Quick Test of Installed RPCs - Mid West |  | 1d | 2002-09-25 | 2002-09-26 | 502 | 5.5d | 3d |  | IFRA; FW; DIFR; BBR | 32h |
| 504 | 3.12.1.37 | Transport Old Mid West Chambers to CEH |  | 1d | 2002-09-24 | 2002-09-25 | 501 | 2.5d | 0d |  | HC; DIFR; BBR | 24h |
| 505 | 3.12.1.38 | Install Work Platfrom - Mid East |  | 1d | 2002-09-25 | 2002-09-26 | 504 | 2.5d | 0d |  | HC; CR; FE; DIFR; BBR | 40h |
| 506 | 3.12.1.39 | Transport New Mid East Chambers to IR-2 |  | 1d | 2002-09-26 | 2002-09-27 | 505 | 2.5d | 0d |  | HC; DIFR; BBR | 24h |
| 507 | 3.12.1.40 | Install Brass Absorber - Mid East |  | 1d | 2002-09-27 | 2002-09-30 | 506 | 2.5d | 0d |  | HC; CR; FE; DIFR; BBR | 40h |
| 508 | 3.12.1.42 | Weld Standoff Frame Brackets on Lower CWs |  | 1d | 2002-09-03 | 2002-09-03 |  | 0d |  | must start on 2002-09-03 | MFD; DIFR; BBR | 24h |
| 509 | 3.12.1.43 | Weld Layer 18 &19 Module Brackets - West |  | 3d | 2002-09-04 | 2002-09-06 | 508 | 34.2d | 0d |  | MFD; DIFR; BBR; FW | 96h |
| 510 | 3.12.1.44 | Weld Layer 18 &19 Module Brackets - East |  | 4d | 2002-09-09 | 2002-09-12 | 509 | 34.2d | 31.7d |  | MFD; FE; DIFR; BBR | 128h |
| 511 | 3.12.1.45 | Rem & Install Chambers - Mid East |  | 1d | 2002-09-30 | 2002-10-01 | 507 | 2.5d | 0d |  | HC; CR; FE; DIFR; BBR | 40h |
| 512 | 3.12.1.46 | Connect RPC Gas - Mid East |  | 1d | 2002-10-01 | 2002-10-02 | 511, 503 | 2.5d | 0d |  | IFRA; FE; DIFR; BBR | 32h |
| 513 | 3.12.1.47 | Quick Test of Installed RPCs - Mid East |  | 1d | 2002-10-02 | 2002-10-03 | 512 | 21.2d | 10.3d |  | IFRA; FE; DIFR; BBR | 32h |
| 514 | 3.12.1.48 | Transport Old Mid East Chambers to CEH |  | 1d | 2002-10-01 | 2002-10-02 | 511 | 32.35d |  |  | HC; DIFR; BBR | 24h |
| 515 | 3.12.1.49 | Remove Work Platform - Mid West |  | 1d | 2002-10-02 | 2002-10-03 | 512 | 2.5d | 0d |  | HC; CR; FW; DIFR; BBR | 40h |
| 516 | 3.12.1.51 | Install Flux Bar 4 - West |  | 1d | 2002-10-03 | 2002-10-04 | 515 | 2.5d | 0d |  | HC; CR; FW; DIFR; BBR | 40h |
| 517 | 3.12.1.52 | Install Flux Bar 3 - West |  | 1d | 2002-10-04 | 2002-10-07 | 516 | 2.5d | 0d |  | HC; CR; FW; DIFR; BBR | 40h |
| 518 | 3.12.1.53 | Remove Work Platform - Mid East |  | 1d | 2002-10-07 | 2002-10-08 | 517 | 2.5d | 0d |  | HC; CR; FE; DIFR; BBR | 40h |
| 519 | 3.12.1.55 | Install Flux Bar 4 - East |  | 1d | 2002-10-08 | 2002-10-09 | 518 | 2.5d | 0d |  | HC; CR; FE; DIFR; BBR | 40h |
| 520 | 3.12.1.56 | Install Flux Bar 3 - East |  | 1d | 2002-10-09 | 2002-10-10 | 519 | 2.5d | 0d |  | HC; CR; FE; DIFR; BBR | 40h |
| 521 | 3.12.1.57 | Remove CW from End Door Skid - West |  | 0.1d | 2002-10-10 | 2002-10-10 | 520 | 2.5d | 0d |  | HC; CR; FW; DIFR; BBR | 4h |
| 522 | 3.12.1.58 | Install Lower CW - West |  | 0.1d | 2002-10-10 | 2002-10-10 | 521, 508 | 2.5d | 0d |  | HC; CR; FW; DIFR; BBR | 4h |
| 523 | 3.12.1.59 | Remove CW from End Door Skid - East |  | 0.1d | 2002-10-10 | 2002-10-10 | 522 | 2.5d | 0d |  | HC; CR; FE; DIFR; BBR | 4h |
| 524 | 3.12.1.60 | Install Lower CW - East |  | 0.1d | 2002-10-10 | 2002-10-10 | 523, 508 | 2.5d | 0d |  | HC; CR; FE; DIFR; BBR | 4h |
| 525 | 3.12.1.61 | Install Minicr Racks - West |  | 0.25d | 2002-10-10 | 2002-10-10 | 524 | 2.5d | 0d |  | HC; CR; FW; DIFR; BBR | 10h |
| 526 | 3.12.1.62 | Install Minicr Racks - East |  | 0.25d | 2002-10-10 | 2002-10-11 | 525 | 2.5d | 0d |  | HC; CR; FE; DIFR; BBR | 10h |
| 527 | 3.12.1.63 | MINICRATE RACKS INSTALLED | milestone | 0d | 2002-10-11 | 2002-10-11 | 526 | 25.45d |  |  | DIFR; IFRA; IFRB; BBR |  |
| 528 | 3.12.1.64 | Install New Gleason Support - West |  | 0.25d | 2002-10-11 | 2002-10-11 | 44, 526 | 2.5d | 0d |  | HC; DIFR; BBR; FW | 8h |
| 529 | 3.12.1.65 | Install New Gleason Support - East |  | 0.25d | 2002-10-11 | 2002-10-11 | 528 | 2.5d | 0d |  | HC; DIFR; FE; BBR | 8h |
| 530 | 3.12.1.66 | Route AC,DAQ from Gleason to CW Racks |  | 2d | 2002-10-11 | 2002-10-15 | 529 | 22.95d |  |  | IFRB; FE; FW; DIFR; BBR | 80h |
| 531 | 3.12.1.67 | Install Racks for HV and Gas |  | 0.25d | 2002-10-11 | 2002-10-11 | 529 | 2.5d | 0d |  | HC; FE; FW; DIFR; BBR; CR | 12h |

| ID | WBS | Task | Type | Duration | Start | Finish | Predecessors | Total slack | Free slack | Resources | Work |
| --- | --- | --- | --- | --- | --- | --- | --- | --- | --- | --- | --- |
| 532 | 3.12.1.68 | Route HV from Gleason to CW Racks |  | 2d | 2002-10-11 | 2002-10-15 | 528, 529, 531 | 14.2d | 0d | IFRB; FE; FW; DIFR; BBR | 80h |
| 533 | 3.12.1.69 | Route Gas from Gleason to CW Racks |  | 1d | 2002-10-15 | 2002-10-16 | 532 | 14.2d | 0d | IFRB; FE; FW; DIFR; BBR | 40h |
| 534 | 3.12.1.70 | Install Lower Raceways/Recable Lower Half of Detector |  | 2d | 2002-10-16 | 2002-10-18 | 533 | 14.2d | 0d | IFRB; FE; FW; DIFR; BBR | 80h |
| 535 | 3.12.1.71 | Connect Gas and HV - Lower |  | 1d | 2002-10-18 | 2002-10-21 | 534 | 14.2d | 5.85d | IFRB; FE; FW; DIFR; BBR | 40h |
| 536 | 3.12.1.73 | Install Work Platform - Mid West |  | 0.25d | 2002-10-11 | 2002-10-14 | 531 | 2.5d | 0d | HC; CR; FW; DIFR; BBR | 10h |
| 537 | 3.12.1.75 | Install Work Platform - Upr West |  | 0.25d | 2002-10-14 | 2002-10-14 | 536 | 2.5d | 0d | HC; CR; FW; DIFR; BBR | 10h |
| 538 | 3.12.1.76 | Transport New Upr West Chambers to IR-2 |  | 0.15d | 2002-10-14 | 2002-10-14 | 537 | 2.5d | 0d | HC; DIFR; BBR | 3.6h |
| 539 | 3.12.1.77 | Install Brass Absorber - Upper West |  | 1d | 2002-10-14 | 2002-10-15 | 538 | 2.5d | 0d | HC; CR; FW; DIFR; BBR | 40h |
| 540 | 3.12.1.78 | Rem & Install Chambers - Upr West |  | 2d | 2002-10-15 | 2002-10-17 | 539 | 2.5d | 0d | HC; CR; FW; DIFR; BBR | 80h |
| 541 | 3.12.1.79 | Connect RPC Gas - Upr West |  | 0.15d | 2002-10-17 | 2002-10-17 | 540, 513 | 10.9d | 0d | IFRA; FW; DIFR; BBR | 4.8h |
| 542 | 3.12.1.80 | Quick Test of Installed RPCs - Upr West |  | 1d | 2002-10-17 | 2002-10-18 | 541 | 10.9d | 2.65d | IFRA; FW; DIFR; BBR | 32h |
| 543 | 3.12.1.81 | Install Work Platform - Mid East |  | 0.25d | 2002-10-17 | 2002-10-17 | 540 | 2.5d | 0d | HC; CR; FE; DIFR; BBR | 10h |
| 544 | 3.10.2.66 | Retrieve Upr East & Upr West Flux Bars From Shop |  | 0.2d | 2002-10-17 | 2002-10-17 | 543 | 20.6d |  | HC; CR; DIFR; BBR | 6.4h |
| 545 | 3.12.1.82 | Install Work Platform - Uppr East |  | 0.25d | 2002-10-17 | 2002-10-17 | 543 | 2.5d | 0d | HC; CR; FE; DIFR; BBR | 10h |
| 546 | 3.12.1.83 | Transport Old Upr West Chambers to CEH |  | 0.15d | 2002-10-18 | 2002-10-18 | 545 | 2.5d | 0d | HC; DIFR; BBR | 3.6h |
| 547 | 3.12.1.84 | Transport New Upr East Chambers to IR-2 |  | 0.15d | 2002-10-18 | 2002-10-18 | 546 | 2.5d | 0d | HC; DIFR; BBR | 3.6h |
| 548 | 3.12.1.85 | Install Brass Absorber - Uppr East |  | 1d | 2002-10-18 | 2002-10-21 | 547 | 2.5d | 0d | HC; CR; FE; DIFR; BBR | 40h |
| 549 | 3.12.1.86 | Rem & Install Chambers - Uppr East |  | 2d | 2002-10-21 | 2002-10-23 | 548 | 2.5d | 0d | HC; CR; FE; DIFR; BBR | 80h |
| 550 | 3.12.1.87 | Transport Old Upr East Chambers to CEH |  | 0.15d | 2002-10-23 | 2002-10-23 | 549 | 2.5d | 0d | HC; DIFR; BBR | 3.6h |
| 551 | 3.12.1.88 | Connect and Flow RPC Gas - Upr East |  | 1d | 2002-10-23 | 2002-10-24 | 549, 542 | 8.25d | 0d | IFRA; FE; DIFR; BBR | 32h |
| 552 | 3.12.1.89 | Quick Test of Installed RPCs - Upr East |  | 1d | 2002-10-24 | 2002-10-25 | 551 | 8.25d | 0d | IFRA; FE; DIFR; BBR | 32h |
| 553 | 3.12.1.90 | IFR CHAMBERS/BRASS ABSORBER INSTALLED | milestone | 0d | 2002-10-25 | 2002-10-25 | 550, 552 | 15.25d |  | HC; IFRB; IFRA; DIFR; BBR |  |
| 554 | 3.12.1.91 | Remove Work Platforms - West |  | 0.5d | 2002-10-23 | 2002-10-23 | 550 | 2.5d | 0d | HC; CR; FW; DIFR; BBR | 20h |
| 555 | 3.12.1.92 | Remove Work Platforms - East |  | 0.5d | 2002-10-23 | 2002-10-24 | 554 | 16.1d |  | HC; CR; FE; DIFR; BBR | 20h |
| 556 | 3.10.2.78 | Open FWD End Doors |  | 0.6d | 2002-10-23 | 2002-10-24 | 554 | 2.5d | 0d | HC; FE; FW; BBR | 19.2h |
| 557 | 3.12.1.94 | Install Flux Bar 2 - West |  | 0.25d | 2002-10-24 | 2002-10-24 | 556 | 2.5d | 0d | HC; CR; FW; DIFR; BBR | 10h |
| 558 | 3.12.1.95 | Install Flux Bar 1 West |  | 0.25d | 2002-10-24 | 2002-10-25 | 557 | 2.5d | 0d | HC; CR; FW; DIFR; BBR | 10h |
| 559 | 3.12.1.96 | Install Flux Bar 2 - East |  | 0.25d | 2002-10-25 | 2002-10-25 | 558 | 2.5d | 0d | HC; CR; FE; DIFR; BBR | 10h |
| 560 | 3.12.1.97 | Install Flux Bar 1 - East |  | 0.25d | 2002-10-25 | 2002-10-25 | 559 | 2.5d | 0d | HC; CR; FE; DIFR; BBR | 10h |
| 561 | 3.12.1.98 | Install Upper Raceways/Recable Upper Half of Detector |  | 2d | 2002-10-25 | 2002-10-29 | 560, 552 | 8d | 0d | IFRA; FE; FW; DIFR; BBR | 80h |
| 562 | 3.12.1.99 | Connect Gas and HV (Mid & Upr) |  | 2d | 2002-10-29 | 2002-10-31 | 561 | 8d | 0d | IFRA; FE; FW; DIFR; BBR | 80h |
| 563 | 3.12.1.100 | Final Test of All Inner Installed RPCs |  | 1d | 2002-10-31 | 2002-11-01 | 562 | 8d | 0d | IFRA; FE; FW; DIFR; BBR | 40h |
| 564 | 3.12.1.101 | Cosmic Ray Tests All Inner Installed RPCs |  | 2d | 2002-11-01 | 2002-11-05 | 563 | 8d |  | IFRA; FE; FW; DIFR; BBR | 80h |
| 565 | 3.12.1.102 | Install Lower Southeast Walkway |  | 0.15d | 2002-10-25 | 2002-10-25 | 560 | 2.5d | 0d | HC; CR; FE; DIFR; BBR | 6h |
| 566 | 3.12.1.103 | Insert Layer 18 & 19 Modules - East |  | 1d | 2002-10-25 | 2002-10-28 | 565, 509 | 2.5d | 0d | HC; CR; FW; DIFR; BBR | 40h |
| 567 | 3.12.1.104 | Insert Layer 18 & 19 Modules - West |  | 1d | 2002-10-28 | 2002-10-29 | 566, 510 | 2.5d | 0d | HC; CR; FE; DIFR; BBR | 40h |
| 568 | 3.12.1.105 | LAYER 18 & 19 MODULES INSTALLED | milestone | 0d | 2002-10-29 | 2002-10-29 | 567 | 8.35d | 0d | FE; FW; DIFR; BBR |  |
| 569 | 3.12.1.106 | Install Upper Walkway - West |  | 0.25d | 2002-10-29 | 2002-10-29 | 567 | 2.5d | 0d | HC; CR; FW; DIFR; BBR | 10h |
| 570 | 3.12.1.107 | Connect Gas & HV Layers 18 & 19 |  | 1d | 2002-10-29 | 2002-10-30 | 535, 568 | 8.35d | 0d | IFRB; FE; FW; DIFR; BBR | 40h |
| 571 | 3.10.2.93 | Retrieve Top Flux Bars From Shop |  | 1d | 2002-10-30 | 2002-10-31 | 570 | 10.85d |  | HC; CR; DIFR; BBR | 32h |
| 572 | 3.12.1.108 | Connect DAQ Cables Layers 18 & 19 |  | 1d | 2002-10-30 | 2002-10-31 | 570 | 8.35d | 0d | IFRB; FE; FW; DIFR; BBR | 40h |
| 573 | 3.12.1.109 | Final Test of All Layer 18 & 19 RPCs |  | 0.5d | 2002-10-31 | 2002-11-01 | 572 | 8.35d | 0d | IFRB; FE; FW; DIFR; BBR | 20h |
| 574 | 3.12.1.110 | Cosmic Ray Tests All Layer 18 & 19 RPCs |  | 2d | 2002-11-01 | 2002-11-05 | 573 | 8.35d |  | IFRB; FE; FW; DIFR; BBR | 80h |
| 575 | 3.12.1.111 | Modify Upper End Door Platform - West |  | 1d | 2002-10-29 | 2002-10-30 | 569 | 2.5d | 0d | HC; CR; DIFR; BBR | 32h |
| 576 | 3.12.1.112 | Modify Upper End Door Platform - East |  | 1d | 2002-10-30 | 2002-10-31 | 575 | 2.5d | 0d | HC; CR; DIFR; BBR | 32h |
| 577 | 3.12.1.113 | Install Cooling Loops/Hoses/Insulation (Flux Bars) |  | 1d | 2002-10-29 | 2002-10-30 | 569 | 11.6d |  | HC; FE; FW; DIFR; BBR | 40h |
| 578 | 3.12.1.114 | Install Belt RPCs - Lwr West |  | 2d | 2002-10-31 | 2002-11-04 | 106, 108, 576 | 2.5d | 0d | HC; CR; FW; DIFR; BBR | 80h |
| 579 | 3.12.1.115 | Install Belt RPCs - Lwr East |  | 1d | 2002-11-04 | 2002-11-05 | 578 | 2.5d | 0d | HC; CR; FE; DIFR; BBR | 40h |
| 580 | 3.12.1.116 | Install Belt RPCs - Upr West |  | 0.5d | 2002-11-05 | 2002-11-06 | 579 | 2.5d | 0d | HC; CR; FW; DIFR; BBR | 20h |
| 581 | 3.12.1.117 | Install Belt RPCs - Upr East |  | 0.5d | 2002-11-06 | 2002-11-06 | 580 | 2.5d | 0d | HC; CR; FE; DIFR; BBR | 20h |
| 582 | 3.12.1.118 | Replace Top Flux Bar - West |  | 0.1d | 2002-11-06 | 2002-11-07 | 581 | 2.5d | 0d | HC; CR; FW; DIFR; BBR | 4h |
| 583 | 3.12.1.119 | Replace Top Flux Bar - East |  | 0.1d | 2002-11-07 | 2002-11-07 | 582 | 2.5d | 0d | HC; CR; FE; DIFR; BBR | 4h |
| 584 | 3.12.1.123 | Install Upper Platform - West |  | 0.15d | 2002-11-07 | 2002-11-07 | 583 | 2.5d | 0d | HC; CR; FW; DIFR; BBR | 6h |
| 585 | 3.12.1.124 | Install Upper Platform - East |  | 0.15d | 2002-11-07 | 2002-11-07 | 584 | 2.5d | 0d | HC; CR; FE; DIFR; BBR | 6h |
| 586 | 3.10.2.108 | Modify F-Cal Extraction H-Frame |  | 2d | 2002-11-07 | 2002-11-11 | 585 | 2.5d | 0d | HC; DIFR; BBR; FB | 64h |
| 587 | 3.10.2.109 | Remove EQ Brace - BWD Upr East |  | 0.15d | 2002-11-06 | 2002-11-07 | 581 | 6.3d | 0d | HC; CR; BBR; BE | 4.8h |
| 588 | 3.10.2.110 | Remove Manlift 3 - BWD East |  | 0.05d | 2002-11-07 | 2002-11-07 | 587 | 6.3d | 0d | HC; CR; BBR; BE | 1.6h |
| 589 | 3.10.2.111 | Remove EQ Brace - BWD Lwr East |  | 0.1d | 2002-11-07 | 2002-11-07 | 588 | 6.3d |  | HC; CR; BBR; BE | 3.2h |
| 590 | 3.12.1.120 | Replace Upper Tie Rods - FWD West |  | 0.3d | 2002-11-11 | 2002-11-11 | 586 | 2.5d | 0d | HC; FW; BBR | 7.2h |
| 591 | 3.12.1.121 | Replace Upper Tie Rods - FWD East |  | 0.3d | 2002-11-11 | 2002-11-12 | 590 | 2.5d | 0d | HC; FE; BBR | 7.2h |
| 592 | 3.12.1.125 | Install Belt RPC - Top West |  | 0.7d | 2002-11-11 | 2002-11-12 | 590 | 2.85d | 0d | HC; CR; FW; DIFR; BBR | 28h |
| 593 | 3.12.1.126 | Install Belt RPC - Top East |  | 0.75d | 2002-11-12 | 2002-11-12 | 591 | 2.5d | 0d | HC; CR; FE; DIFR; BBR | 30h |

| ID | WBS | Task | Type | Duration | Start | Finish | Predecessors | Total slack | Free slack | Constraint | Resources | Work |
| --- | --- | --- | --- | --- | --- | --- | --- | --- | --- | --- | --- | --- |
| 594 | 3.12.2 | **Prepare for Backward Raft Installation** |  | 0.1d | 2002-10-08 | 2002-10-08 |  | 2.4d |  |  | PEP; BBR; HC | 6.4h |
| 595 | 3.12.2.2 | Install Shielding Block - BWD West |  | 0.1d | 2002-10-08 | 2002-10-08 |  | 2.4d | 0d | start no earlier than 2002-10-08 | HC; CR; BW; PEP; BBR | 4h |
| 596 | 3.12.3 | **Barrel IFR Work** |  | 42d | 2002-08-13 | 2002-10-10 |  | 25.55d |  |  | BBR; BIFR; HC | 1840h |
| 597 | 3.12.3.5 | IFR Barrel Gas Upgrade - FWD East (1st Half) |  | 3d | 2002-08-13 | 2002-08-15 | 319 | 64.55d |  | start no earlier than 2002-08-13 | IFRG; BIFR; FE; BBR | 96h |
| 598 | 3.10.4.2 | IFR Barrel Gas Upgrade - FWD East (2nd Half) |  | 3d | 2002-08-26 | 2002-08-28 |  | 55.55d |  | start no earlier than 2002-08-26 | IFRG; BIFR; FE; BBR | 96h |
| 599 | 3.12.3.6 | IFR Barrel Gas Upgrade - FWD West (1st Half) |  | 4d | 2002-08-19 | 2002-08-22 |  | 57.55d | 22.2d | start no earlier than 2002-08-19 | IFRG; FW; BIFR; BBR | 128h |
| 600 | 3.12.3.7 | IFR Barrel Gas Upgrade - FWD West (2nd Half) |  | 2d | 2002-09-25 | 2002-09-27 | 599, 504 | 35.35d |  | start no earlier than 2002-08-30 | IFRG; FW; BIFR; BBR | 64h |
| 601 | 3.12.3.8 | Repair Barrel IFR Chains With Broken FECs - FWD West |  | 8d | 2002-09-23 | 2002-10-02 |  | 25.55d | 0d | start no earlier than 2002-09-23 | IFRF; FW; BIFR; BBR | 256h |
| 602 | 3.12.3.9 | Repair Barrel IFR Chains With Broken FECs - FWD East (1st Half) |  | 6d | 2002-10-03 | 2002-10-10 | 601 | 25.55d |  |  | IFRF; FE; BIFR; BBR | 192h |
| 603 | 3.10.5 | **EMC Work** |  | 2d | 2002-08-09 | 2002-08-12 |  | 67.55d |  |  |  | 48h |
| 604 | 3.10.5.1 | Remove,Repair & Install PIN Diodes - FWD West |  | 1d | 2002-08-09 | 2002-08-09 |  | 67.55d | 0d | start no earlier than 2002-08-09 | EMC; BBR; FW | 24h |
| 605 | 3.10.5.2 | Remove,Repair & Install PIN Diodes - FWD East |  | 1d | 2002-08-12 | 2002-08-12 | 604 | 67.55d |  |  | EMC; BBR; FE | 24h |
| 606 | 3.18.2 | **DIRC Work** |  | 11d | 2002-08-16 | 2002-08-30 |  | 53.55d |  |  | DIRC; BBR | 461.6h |
| 607 | 3.18.2.1 | Install DIRC Access Platform |  | 0.1d | 2002-08-16 | 2002-08-16 |  | 59.45d | 0d | start no earlier than 2002-08-16 | HC; CR; DIRC; BBR; BB | 4h |
| 608 | 3.18.2.2 | Install DIRC DFBs |  | 4.9d | 2002-08-16 | 2002-08-22 | 607 | 59.45d | 0d |  | DIRC; BBR; BB | 117.6h |
| 609 | 3.18.2.3 | Remove DIRC Access Platform |  | 0.1d | 2002-08-23 | 2002-08-23 | 608 | 59.45d |  |  | HC; CR; DIRC; BB; BBR | 4h |
| 610 | 3.10.6.4 | Water Sensor Maintenance |  | 5d | 2002-08-26 | 2002-08-30 |  | 53.55d |  | start no earlier than 2002-08-26 | DIRC; BE; BW; BBR | 160h |
| 611 | 3.13.4 | **End Doors, BaBar Mechanical Support and Maintenance** |  | 67.05d | 2002-08-09 | 2002-11-13 |  | 2.5d |  |  | HC; BBR; PEP | 2410.8h |
| 612 | 3.10.7.1 | Remove EQ Braces - FWD East |  | 1d | 2002-08-09 | 2002-08-09 |  | 2.5d | 0d | start no earlier than 2002-08-09 | HC; CR; FE; BBR | 32h |
| 613 | 3.10.7.2 | Remove EQ Braces - FWD West |  | 1d | 2002-08-12 | 2002-08-12 | 612 | 2.5d | 0d |  | HC; CR; FW; BBR | 32h |
| 614 | 3.12.1.2 | Remove Upper CW - East |  | 1d | 2002-08-13 | 2002-08-13 | 613 | 2.5d | 0d |  | HC; CR; FE; DIFR; BBR | 40h |
| 615 | 3.12.1.3 | Remove Lower CW - East |  | 1d | 2002-08-14 | 2002-08-14 | 614 | 2.5d | 0d |  | HC; CR; FE; DIFR; BBR | 40h |
| 616 | 3.12.1.4 | Move Upper West CW to East End Door Skid |  | 1d | 2002-08-15 | 2002-08-15 | 615 | 2.5d | 0d |  | CR; FE; FW; DIFR; BBR; HC | 48h |
| 617 | 3.12.1.5 | Remove Lower CW - West |  | 1d | 2002-08-16 | 2002-08-16 | 616 | 2.5d | 0d |  | HC; CR; FW; DIFR; BBR | 40h |
| 618 | 3.12.1.6 | Place Upper East CW on West End Door Skid |  | 1d | 2002-08-19 | 2002-08-19 | 617 | 2.5d | 0d |  | HC; CR; FE; FW; DIFR; BBR | 48h |
| 619 | 3.12.1.9 | Setup RPC Staging Area | milestone | 0d | 2002-08-19 | 2002-08-19 | 618 | 2.5d | 0d |  | HC; CR; DIFR; BBR |  |
| 620 | 3.10.7.9 | Remove Manlift 1 - FWD |  | 1d | 2002-08-20 | 2002-08-20 | 619 | 61.55d |  |  | HC; CR; BBR | 24h |
| 621 | 3.10.7.10 | Close FWD End Doors (IFR Brass & RPCs) |  | 1d | 2002-08-20 | 2002-08-20 | 619 | 2.5d | 0d |  | HC; DIFR; BBR | 24h |
| 622 | 3.12.1.10 | Remove Lower Southeast Walkway |  | 1d | 2002-08-21 | 2002-08-21 | 621 | 2.5d | 0d |  | HC; CR; FE; DIFR; BBR | 40h |
| 623 | 3.12.1.11 | Remove Lower Southeast Stair |  | 1d | 2002-08-22 | 2002-08-22 | 622 | 2.5d | 0d |  | HC; CR; FE; DIFR; BBR | 40h |
| 624 | 3.10.7.13 | Radius Cam Follower Grooves - BWD West |  | 1d | 2002-09-25 | 2002-09-25 |  | 33.55d | 0d | start no earlier than 2002-09-25 | HC; DIFR; BBR; BW | 32h |
| 625 | 3.10.7.14 | Radius Cam Follower Grooves - BWD East |  | 1d | 2002-09-26 | 2002-09-26 | 624 | 33.55d | 0d |  | HC; DIFR; BE; BBR | 32h |
| 626 | 3.10.7.15 | Radius Cam Follower Grooves - FWD East |  | 1d | 2002-09-27 | 2002-09-27 | 625 | 33.55d | 0d |  | HC; FE; DIFR; BBR | 32h |
| 627 | 3.10.7.16 | Radius Cam Follower Grooves - FWD West |  | 1d | 2002-09-30 | 2002-09-30 | 626 | 33.55d |  |  | HC; FW; DIFR; BBR | 32h |
| 628 | 3.10.7.17 | Remove Eq Braces - Upr BWD West |  | 0.15d | 2002-09-27 | 2002-09-27 |  | 35.25d | 0d | start no earlier than 2002-09-27 | HC; CR; BW; BBR | 4.8h |
| 629 | 3.10.7.18 | Remove Manlift 2 - BWD West |  | 0.05d | 2002-09-27 | 2002-09-27 | 628 | 35.25d | 0d |  | HC; CR; BW; BBR | 1.6h |
| 630 | 3.10.7.19 | Remove EQ Brace - BWD Upr West |  | 0.1d | 2002-09-27 | 2002-09-27 | 629 | 35.25d |  |  | HC; CR; BW; BBR | 3.2h |
| 631 | 3.10.7.20 | Install End Door Feet - BWD West |  | 2d | 2002-09-30 | 2002-10-01 |  | 24.55d | 0d | start no earlier than 2002-09-30 | HC; BW; BBR | 48h |
| 632 | 3.10.7.21 | Install Tie Rods - BWD Lwr West |  | 2d | 2002-10-02 | 2002-10-03 | 631 | 24.55d | 0d |  | HC; BW; BBR | 48h |
| 633 | 3.10.7.22 | Install Tie Rods - BWD Upr West |  | 1d | 2002-10-04 | 2002-10-04 | 632 | 24.55d | 0d |  | HC; BW; BBR | 24h |
| 634 | 3.10.7.23 | Install End Door Feet - BWD East |  | 2d | 2002-10-07 | 2002-10-08 | 633 | 24.55d | 0d |  | HC; BW; BBR | 48h |
| 635 | 3.10.7.24 | Install Tie Rods - BWD Lwr East |  | 2d | 2002-10-09 | 2002-10-10 | 634 | 24.55d | 0d |  | HC; BW; BBR | 48h |
| 636 | 3.10.7.25 | Install Tie Rods - BWD Upr East |  | 1d | 2002-10-11 | 2002-10-11 | 635 | 24.55d |  |  | HC; BW; BBR | 24h |
| 637 | 3.10.7.26 | Install EQ Braces - FWD West |  | 0.25d | 2002-11-12 | 2002-11-12 | 592 | 2.85d |  |  | HC; CR; FW; BBR | 8h |
| 638 | 3.10.7.27 | Install EQ Braces - FWD East |  | 0.25d | 2002-11-12 | 2002-11-13 | 593 | 2.5d |  |  | HC; CR; FE; BBR | 8h |

| ID | WBS | Task | Type | Duration | Start | Finish | Predecessors | Total slack | Free slack | Resources | Work |
| --- | --- | --- | --- | --- | --- | --- | --- | --- | --- | --- | --- |
| 640 | 3.13 | **ST Repairs** |  | 47.9d | 2002-08-01 | 2002-10-09 |  | 2.5d |  | PEP; BBR | 1482.4h |
| 641 | 3.13.1 | Transport ST to Cleanroom |  | 1d | 2002-08-01 | 2002-08-02 | 467 | 3.9d | 1.4d | PEP; Riggers | 16h |
| 642 | 3.13.2 | Setup ST on Table |  | 3d | 2002-08-06 | 2002-08-08 | 641, 194, 193, 195, 200 | 2.5d | 0d | PEP; S.Ecklund | 48h |
| 643 | 3.13.3 | Remove ST Outer Shell |  | 5d | 2002-08-09 | 2002-08-15 | 642 | 2.5d | 0d | PEP; S.Ecklund | 80h |
| 644 | 3.13.4 | Remove SVT |  | 5d | 2002-08-16 | 2002-08-22 | 643 | 2.5d | 0d | PEP; SVT Tech | 80h |
| 645 | 3.13.5 | Add Cooling to Bellows |  | 13d | 2002-08-23 | 2002-09-11 | 644 | 2.5d | 0d | PEP; S.Ecklund | 208h |
| 646 | 3.13.6 | Install & Test SVT |  | 10d | 2002-09-12 | 2002-09-25 | 645 | 2.5d | 0d | PEP; SVT Tech | 160h |
| 647 | 3.13.8 | Install ST Outer Shell |  | 6d | 2002-09-26 | 2002-10-03 | 646 | 2.5d | 0d | PEP; S.Ecklund | 96h |
| 648 | 3.13.7 | Test SVT |  | 3d | 2002-10-04 | 2002-10-08 | 647 | 2.5d | 0d | PEP; SVT Tech | 48h |
| 649 | 3.13.9 | Transport ST to IR-2 |  | 0.5d | 2002-10-09 | 2002-10-09 | 648 | 2.5d | 0.1d | PEP; Riggers | 8h |
| 651 | 3.14 | **OPEN FORWARD DOORS** |  | 1.5d | 2002-10-08 | 2002-10-09 |  | 2.4d |  | PEP; BBR | 84h |
| 652 | 3.14.1 | FWD End Doors Open (Inst FWD Raft, ST) | milestone | 0d | 2002-10-08 | 2002-10-08 | 595 | 2.4d | 0d | HC; ED; PEP; FE; FW; BBR |  |
| 653 | 3.14.2 | Install FWD PEP Raft Support pedastal top plate |  | 1d | 2002-10-08 | 2002-10-09 | 652, 199 | 2.4d | 0d | HC; CR; PEP; FB; BBR | 40h |
| 654 | 3.14.3 | Install Extension Table |  | 0.25d | 2002-10-09 | 2002-10-09 | 653 | 2.4d | 0d | HC; CR; PEP; FB; BBR | 10h |
| 655 | 3.14.4 | Install ST Temp Support |  | 0.25d | 2002-10-09 | 2002-10-09 | 654 | 2.4d | 1.05d | HC; CR; PEP; FB; BBR | 10h |
| 657 | 3.15 | **Install ST** |  | 2.5d | 2002-10-09 | 2002-10-14 |  | 2.4d |  | PEP; BBR | 146h |
| 658 | 3.15.1 | Pick Up ST with Spreader Bar, Set on Installation Beam |  | 0.25d | 2002-10-09 | 2002-10-09 | 655, 649 | 2.4d | 0d | HC; CR; PEP; FB; BBR | 10h |
| 659 | 3.15.2 | Roll In ST, Set on Temp Frames Front & Rear |  | 2d | 2002-10-09 | 2002-10-11 | 658 | 2.4d | 0d | HC; CR; PEP; FB; BB; BBR; DT | 112h |
| 660 | 3.15.3 | Remove BWD Insertion Beam and Roller Frames |  | 0.25d | 2002-10-11 | 2002-10-14 | 659 | 2.4d | 0d | HC; CR; PEP; BB; BBR; DT | 12h |
| 662 | 3.16 | **Install Forward Raft** |  | 10.5d | 2002-10-14 | 2002-10-28 |  | 2.4d |  | PEP; BBR | 516h |
| 663 | 3.16.1 | **Position Raft** |  | 3.5d | 2002-10-14 | 2002-10-17 |  | 2.4d |  | PEP; BBR | 120h |
| 664 | 3.16.1.1 | Crane in Raft |  | 1d | 2002-10-14 | 2002-10-15 | 660 | 2.4d | 0d | PEP; HC; CR; BBR; FB | 40h |
| 665 | 3.16.1.2 | Bolt down raft |  | 0.5d | 2002-10-15 | 2002-10-15 | 664 | 2.4d | 0d | PEP; MFD | 8h |
| 666 | 3.16.1.3 | Align Raft |  | 0.75d | 2002-10-15 | 2002-10-16 | 665 | 2.4d | 0d | PEP; ALIGN | 12h |
| 667 | 3.14.1.4 | Insert dowel pin |  | 0.25d | 2002-10-16 | 2002-10-16 | 666 | 2.4d | 0d | PEP; SJM | 4h |
| 668 | 3.16.1.4 | Reinstall Yoke |  | 0.25d | 2002-10-16 | 2002-10-16 | 667 | 2.4d | 0d | PEP; MFD | 4h |
| 669 | 3.16.1.5 | Setdown ST on Raft |  | 0.25d | 2002-10-16 | 2002-10-17 | 668 | 2.4d | 0d | PEP; MFD | 4h |
| 670 | 3.16.1.6 | Remove Temp Support Frame |  | 0.5d | 2002-10-17 | 2002-10-17 | 669, 741 | 2.4d | 0d | PEP; HC; CR; FB; BBR | 20h |

| ID | WBS | Task | Duration | Start | Finish | Predecessors | Total slack | Free slack | Constraint | Resources | Work |
| --- | --- | --- | --- | --- | --- | --- | --- | --- | --- | --- | --- |
| 671 | 3.16.2 | **Reconnect Forward Vacuum** | 2.75d | 2002-10-16 | 2002-10-21 |  | 3.65d |  |  | PEP | 64h |
| 672 | 3.16.2.1 | Install Forward Frangible Link | 2d | 2002-10-16 | 2002-10-18 | 666 | 20.2d |  |  | PEP; MFD | 32h |
| 673 | 3.16.2.2 | Install Forward Q1/Q2 Bellows | 1.5d | 2002-10-17 | 2002-10-21 | 670 | 2.4d | 0d |  | PEP; MFD | 24h |
| 674 | 3.16.3 | **Reconnect Forward PEPII Services** | 6.75d | 2002-10-16 | 2002-10-25 |  | 5.15d |  |  | PEP | 160h |
| 675 | 3.16.3.1 | Reconnect Pipes, Manifolds & Cables at Front of Raft | 4d | 2002-10-21 | 2002-10-25 | 673 | 2.4d | 0d |  | PEP; MFD | 64h |
| 676 | 3.16.3.2 | Reconnect to Water Manifolds | 1d | 2002-10-16 | 2002-10-17 | 666 | 18.7d | 0d |  | PEP; MFD | 16h |
| 677 | 3.16.3.3 | Reconnect Power Cables | 2d | 2002-10-17 | 2002-10-21 | 676 | 18.7d | 0d |  | PEP; PC | 32h |
| 678 | 3.16.3.4 | Reconnect TCI Cables | 0.5d | 2002-10-21 | 2002-10-21 | 677 | 18.7d |  |  | PEP; S.Ecklund | 8h |
| 679 | 3.16.4 | **Reconnect Forward SVT Services** | 1.5d | 2002-10-25 | 2002-10-28 |  | 2.4d |  |  | PEP | 32h |
| 680 | 3.16.4.1 | Reconnect White Cables | 1d | 2002-10-25 | 2002-10-28 | 675 | 2.4d | 0d |  | PEP; SVT Tech | 16h |
| 681 | 3.16.4.2 | Reconnect Cooling System | 0.1d | 2002-10-28 | 2002-10-28 | 680 | 2.4d | 0d |  | PEP; SVT Tech | 1.6h |
| 682 | 3.16.4.3 | Reconnect Dry Air Hoses | 0.1d | 2002-10-28 | 2002-10-28 | 681 | 2.4d | 0d |  | PEP; SVT Tech | 1.6h |
| 683 | 3.16.4.4 | Reconnect Position Sensor Cables | 0.15d | 2002-10-28 | 2002-10-28 | 682 | 2.4d | 0d |  | PEP; C.Cheng | 2.4h |
| 684 | 3.16.4.5 | Reconnect EMC Monitoring Board Cables | 0.15d | 2002-10-28 | 2002-10-28 | 683 | 11.95d | 0d |  | PEP; Jong Yi | 2.4h |
| 686 | 3.17 | **CLOSE FORWARD DOORS** | 2d | 2002-10-28 | 2002-10-30 |  | 11.95d |  |  | PEP; BBR; HC | 96h |
| 687 | 3.17.1 | Check All Pipes and Cables Clear Doors | 1d | 2002-10-28 | 2002-10-29 | 684 | 11.95d | 0d |  | PEP; SJM; SVT Tech; DC Tech | 32h |
| 688 | 3.17.2 | Adjust Clearances on Raft Earthquake Bolts | 0.5d | 2002-10-29 | 2002-10-30 | 687 | 11.95d | 0d |  | PEP; SJM | 8h |
| 689 | 3.17.3 | Close Forward End Doors | 0.5d | 2002-10-30 | 2002-10-30 | 688 | 11.95d |  |  | PEP; HC; FE; FW; BBR | 20h |
| 691 | 3.18 | **BABAR WORK, PHASE 3 (Post ST Return)** | 24.55d | 2002-10-14 | 2002-11-15 |  | 0d |  |  | BBR | 1120.4h |
| 692 | 3.18.3 | **Barrel IFR Work** | 2d | 2002-11-04 | 2002-11-05 |  | 7.55d |  |  |  | 64h |
| 693 | 3.12.3.9 | Repair Barrel IFR Chains With Broken FECs - FWD East (2nd Half) | 2d | 2002-11-04 | 2002-11-05 |  | 7.55d |  | start no earlier than 2002-11-04 | IFRF; FE; BIFR; BBR | 64h |
| 694 | 3.18.4 | **End Doors, BaBar Mechanical Support and Maintenance** | 19d | 2002-10-14 | 2002-11-07 |  | 5.55d |  |  | BBR; HC | 636.8h |
| 695 | 3.16.2.1 | Install EQ Brace - BWD Lwr East | 0.15d | 2002-10-14 | 2002-10-14 |  | 24.25d | 0d | start no earlier than 2002-10-14 | HC; CR; BE; BBR | 4.8h |
| 696 | 3.16.2.2 | Insert Manlift 3 - BWD East | 0.05d | 2002-10-14 | 2002-10-14 | 695 | 24.25d | 0d |  | HC; CR; BE; BBR | 1.6h |
| 697 | 3.16.2.3 | Install EQ Brace - BWD Lwr East | 0.1d | 2002-10-14 | 2002-10-14 | 696 | 24.25d |  |  | HC; CR; BE; BBR | 3.2h |
| 698 | 3.16.2.4 | Remove EQ Braces - FWD East | 0.25d | 2002-10-18 | 2002-10-18 |  | 20.3d |  | start no earlier than 2002-10-18 | HC; CR; FE; FW; BBR | 10h |
| 699 | 3.16.2.5 | Install End Door Feet - FWD East | 2d | 2002-10-21 | 2002-10-22 |  | 15.3d | 0d | start no earlier than 2002-10-21 | HC; FE; BBR | 48h |
| 700 | 3.16.2.6 | Remove PEP Shield Block | 0.1d | 2002-10-22 | 2002-10-22 |  | 18.15d | 0d | start no earlier than 2002-10-22 | HC; CR; BBR; PEP | 3.2h |
| 701 | 3.16.2.7 | Install EQ Brace - Lwr BWD West | 0.1d | 2002-10-22 | 2002-10-22 | 700 | 18.15d | 0d |  | HC; CR; BW; BBR | 3.2h |
| 702 | 3.16.2.8 | Insert Manlift 2 - BWD West | 0.05d | 2002-10-22 | 2002-10-22 | 701 | 18.15d | 0d |  | HC; CR; BW; BBR | 1.6h |
| 703 | 3.16.2.9 | Install EQ Brace - BWD Upr West | 0.15d | 2002-10-22 | 2002-10-22 | 702 | 18.15d |  |  | HC; CR; BW; BBR | 4.8h |
| 704 | 3.16.2.10 | Install Tie Rods - Lwr FWD East | 2d | 2002-10-23 | 2002-10-24 | 699 | 15.3d | 0d |  | HC; FE; BBR | 48h |
| 705 | 3.16.2.11 | Remove EQ Braces - Fwd West | 0.25d | 2002-10-25 | 2002-10-25 | 704 | 15.3d |  |  | HC; CR; FW; BBR | 8h |
| 706 | 3.16.2.12 | Install Gap Plates - FWD West | 0.5d | 2002-10-28 | 2002-10-28 |  | 14.05d |  | start no earlier than 2002-10-28 | HC; CR; FW; BBR | 16h |
| 707 | 3.16.2.13 | Install FWD SVT Bridge | 0.1d | 2002-10-29 | 2002-10-29 |  | 11.35d | 0d | start no earlier than 2002-10-29 | HC; CR; FE; FW; BBR | 4h |
| 708 | 3.16.2.14 | Remove SVT FWD Bridge | 0.1d | 2002-10-31 | 2002-10-31 | 707FS+2d | 11.35d |  |  | HC; CR; FE; FW; BBR | 4h |
| 709 | 3.16.2.15 | Install End Door Feet - FWD West | 2d | 2002-11-04 | 2002-11-05 |  | 5.55d | 0d | start no earlier than 2002-11-04 | HC; FW; BBR | 48h |
| 710 | 3.18.3.5 | Install Barrel Gap Filler Plates - BWD Upr East | 0.25d | 2002-11-05 | 2002-11-05 |  | 7.5d | 0d | start no earlier than 2002-11-05 | HC; CR; BE; BIFR; BBR | 10h |
| 711 | 3.16.2.17 | Remove Manlift 2 - BWD East | 0.05d | 2002-11-05 | 2002-11-05 | 710 | 7.5d | 0d |  | HC; CR; BE; BBR | 1.6h |
| 712 | 3.18.3.2 | Install Barrel Gap Filler Plates - BWD Lwr East | 0.2d | 2002-11-05 | 2002-11-05 | 711 | 7.5d | 0d |  | HC; CR; BIFR; BE; BBR | 8h |
| 713 | 3.18.3.6 | Install Barrel Gap Filler Plates - BWD Upr West | 0.25d | 2002-11-05 | 2002-11-05 | 712 | 7.5d | 0d |  | HC; CR; BW; BIFR; BBR | 10h |
| 714 | 3.16.2.20 | Remove Manlift 3 - BWD West | 0.05d | 2002-11-05 | 2002-11-05 | 713 | 7.5d | 0d |  | HC; CR; BW; BBR | 1.6h |
| 715 | 3.18.3.3 | Install Barrel Gap Filler Plates - BWD Lwr West | 0.25d | 2002-11-05 | 2002-11-06 | 714 | 7.5d |  |  | HC; CR; BW; BIFR; BBR | 10h |
| 716 | 3.16.2.22 | Install Gap Filler Plates - FWD East | 0.5d | 2002-11-06 | 2002-11-06 |  | 7.05d |  | start no earlier than 2002-11-06 | HC; CR; FE; BBR | 16h |
| 717 | 3.16.2.23 | Install Tie Rods - Lwr FWD West | 2d | 2002-11-06 | 2002-11-07 | 709 | 5.55d |  |  | HC; FW; BBR | 48h |
| 718 | 3.16.2.24 | Remove EQ Brace - BWD Lwr West | 0.1d | 2002-11-07 | 2002-11-07 |  | 5.95d | 0d | start no earlier than 2002-11-07 | HC; CR; BW; BBR | 3.2h |
| 719 | 3.16.2.25 | Insert Manlift 3 - BWD West | 0.05d | 2002-11-07 | 2002-11-07 | 718 | 5.95d | 0d |  | HC; CR; BW; BBR | 1.6h |
| 720 | 3.16.2.26 | Remove EQ Brace - BWD Upr West | 0.15d | 2002-11-07 | 2002-11-07 | 719 | 5.95d | 0d |  | HC; CR; BW; BBR | 4.8h |
| 721 | 3.16.2.27 | Remove EQ Brace - BWD Lwr East | 0.1d | 2002-11-07 | 2002-11-07 | 720 | 5.95d | 0d |  | HC; CR; BE; BBR | 3.2h |
| 722 | 3.16.2.28 | Insert Manlift 2 - BWD East | 0.05d | 2002-11-07 | 2002-11-07 | 721 | 5.95d | 0d |  | HC; CR; BE; BBR | 1.6h |
| 723 | 3.16.2.29 | Remove EQ Brace - BWD Upr East | 0.15d | 2002-11-07 | 2002-11-07 | 722 | 5.95d |  |  | HC; CR; BE; BBR | 4.8h |

| ID | WBS | Task | Type | Duration | Start | Finish | Predecessors | Total slack | Free slack | Constraint | Resources | Work |
| --- | --- | --- | --- | --- | --- | --- | --- | --- | --- | --- | --- | --- |
| 725 | 3.18.6 | **BABAR CLOSE-UP** |  | 7.55d | 2002-11-06 | 2002-11-15 |  | 0d |  |  | BBR; HC | 223.2h |
| 726 | 3.18.6.1 | Remove EH-to-East Platform Stairway |  | 0.1d | 2002-11-06 | 2002-11-06 |  | 4.5d | 0d | start no earlier than 2002-11-06 | HC; CR; BBR | 2.4h |
| 727 | 3.18.6.2 | Replace 10 Shield Wall Blocks |  | 2d | 2002-11-06 | 2002-11-08 | 726 | 4.5d | 0d |  | HC; CR; PEP; BBR | 64h |
| 728 | 3.18.6.3 | Remove BWD Manlifts |  | 0.1d | 2002-11-08 | 2002-11-08 | 727 | 4.5d | 0d |  | HC; CR; BE; BW; BBR | 4h |
| 729 | 3.18.6.4 | Close BWD End Doors (Final Close-up) |  | 0.1d | 2002-11-08 | 2002-11-08 | 728 | 4.5d | 0d |  | HC; ED; BE; BBR | 3.2h |
| 730 | 3.18.6.5 | Remove Manlift - FWD End |  | 0.05d | 2002-11-08 | 2002-11-08 | 729 | 4.5d | 0d |  | HC; CR; BBR; FE; FW | 2h |
| 731 | 3.18.6.6 | Close FWD End Doors (Final Close-up) |  | 0.1d | 2002-11-08 | 2002-11-08 | 730 | 4.5d | 0d |  | HC; ED; FW; FE; BBR | 4h |
| 732 | 3.18.6.7 | Close Curtain Wall |  | 0.05d | 2002-11-08 | 2002-11-08 | 731 | 4.5d |  |  | HC; CR; BBR; PEP | 1.6h |
| 733 | 3.16.3.8 | Open Curtain Wall |  | 0.05d | 2002-11-15 | 2002-11-15 | 793, 732 | 0d |  |  | HC; CR; BBR; PEP | 1.6h |
| 734 | 3.18.6.8 | Insert DIRC Cyl, Lead and BWD End Plug |  | 0.25d | 2002-11-15 | 2002-11-15 | 733 | 0d |  |  | HC; CR; DT; PEP; BB; BBR | 12h |
| 735 | 3.16.3.10 | Close Curtain Wall |  | 0.05d | 2002-11-15 | 2002-11-15 | 734 | 0.2d |  |  | HC; CR; BBR; PEP | 1.6h |
| 736 | 3.18.6.9 | Hy-Torq End Door Bolts |  | 0.25d | 2002-11-15 | 2002-11-15 | 734 | 0d |  |  | HC; ED; BBR | 6h |
| 737 | 3.18.6.10 | BABAR DETECTOR CLOSED | milestone | 0d | 2002-11-15 | 2002-11-15 | 736 | 0d |  |  | BBR |  |
| 739 | 3.19 | **Install Backward Raft** |  | 14.05d | 2002-10-15 | 2002-11-04 |  | 3.4d |  |  | PEP; BBR; HC | 819.2h |
| 740 | 3.19.1 | **Position Raft** |  | 4.5d | 2002-10-15 | 2002-10-21 |  | 3.4d |  |  | PEP | 126h |
| 741 | 3.19.1.1 | Crane in Raft |  | 1d | 2002-10-15 | 2002-10-16 | 664 | 3.4d | 0d |  | PEP; HC; CR; BBR; BB; DT | 48h |
| 742 | 3.19.1.2 | Rollin and Bolt Down Raft |  | 1d | 2002-10-16 | 2002-10-17 | 741 | 3.65d | 0d |  | PEP; MFD | 16h |
| 743 | 3.19.1.3 | Align Raft |  | 1d | 2002-10-17 | 2002-10-18 | 742 | 3.65d | 0d |  | PEP; ALIGN | 16h |
| 744 | 3.19.1.4 | Setdown ST on Backward Raft |  | 0.25d | 2002-10-18 | 2002-10-18 | 743 | 3.65d | 0d |  | PEP; MFD | 4h |
| 745 | 3.19.1.5 | Align ST |  | 1d | 2002-10-18 | 2002-10-21 | 744 | 3.65d | 0d |  | PEP; ALIGN | 16h |
| 746 | 3.19.1.6 | Remove Temp ST Supports |  | 0.25d | 2002-10-21 | 2002-10-21 | 745 | 3.65d | 0d |  | PEP; MFD | 4h |
| 747 | 3.19.2 | **Reconnect Backward Vacuum** |  | 1.5d | 2002-10-21 | 2002-10-23 |  | 3.65d |  |  | PEP | 36h |
| 748 | 3.19.2.1 | Install Backward Q1/Q2 Bellows |  | 1.5d | 2002-10-21 | 2002-10-23 | 746, 197 | 3.65d | 0d |  | PEP; MFD | 24h |
| 749 | 3.19.3 | **Reconnect Backward PEPII Services** |  | 5.1d | 2002-10-18 | 2002-10-25 |  | 3.75d |  |  | PEP | 140.4h |
| 750 | 3.19.3.1 | Reconnect Pipes, Manifolds & Cables at Front of Raft |  | 2d | 2002-10-23 | 2002-10-25 | 748 | 3.65d | 0d |  | PEP; MFD | 32h |
| 751 | 3.17.3.2 | Switch on Vertex chamber cooling system |  | 0.1d | 2002-10-25 | 2002-10-25 | 750 | 3.65d | 1.25d |  | PEP; SJM | 1.6h |
| 752 | 3.19.3.2 | Reconnect Main Water Cooling System |  | 2d | 2002-10-18 | 2002-10-22 | 743 | 3.75d | 0d |  | PEP; MFD | 32h |
| 753 | 3.19.3.3 | Reconnect Power Cables |  | 2d | 2002-10-22 | 2002-10-24 | 752 | 3.75d | 0d |  | PEP; PC | 32h |
| 754 | 3.19.3.4 | Reconnect TC Cables |  | 1d | 2002-10-24 | 2002-10-25 | 753 | 15.45d |  |  | PEP; S.Ecklund | 16h |

| ID | WBS | Task | Duration | Start | Finish | Predecessors | Total slack | Free slack | Resources | Work |
| --- | --- | --- | --- | --- | --- | --- | --- | --- | --- | --- |
| 755 | 3.19.4 | **Reconnect Backward SVT Services** | 4.7d | 2002-10-28 | 2002-11-04 |  | 2.4d |  | PEP | 98.8h |
| 756 | 3.19.4.1 | Reconnect White Cables at Front of Raft | 1d | 2002-10-28 | 2002-10-29 | 683, 751 | 2.4d | 0d | PEP; SVT Tech | 16h |
| 757 | 3.19.4.2 | Reconnect White Cables at MUX Racks | 3.5d | 2002-10-29 | 2002-11-01 | 756 | 2.4d | 0d | PEP; SVT Tech | 56h |
| 758 | 3.19.4.3 | Reconnect Cooling System | 0.1d | 2002-11-01 | 2002-11-04 | 757 | 2.4d | 0d | PEP; SVT Tech | 1.6h |
| 759 | 3.19.4.4 | Reconnect Dry Air Hoses | 0.1d | 2002-11-04 | 2002-11-04 | 758 | 2.4d | 0d | PEP; SVT Tech | 1.6h |
| 760 | 3.19.5 | **Reconnect Backward DC Services** | 5.7d | 2002-10-24 | 2002-10-31 |  | 3.75d |  | PEP | 122.8h |
| 761 | 3.19.5.1 | Reconnect to Electronics House | 3d | 2002-10-24 | 2002-10-29 | 753 | 3.75d | 0d | PEP; DC Tech | 48h |
| 762 | 3.19.5.2 | Reconnect Chamber Exhaust | 0.25d | 2002-10-29 | 2002-10-29 | 761, 751 | 3.75d | 0d | PEP; DC Tech | 4h |
| 763 | 3.19.5.3 | Reconnect High Voltage Cables | 0.25d | 2002-10-29 | 2002-10-29 | 762 | 3.75d | 0d | PEP; DC Tech | 4h |
| 764 | 3.19.5.4 | Reconnect Low Voltage Cables | 0.25d | 2002-10-29 | 2002-10-29 | 763 | 3.75d | 0d | PEP; DC Tech | 4h |
| 765 | 3.19.5.5 | Reconnect Gas Lines | 0.5d | 2002-10-29 | 2002-10-30 | 764 | 3.75d | 0d | PEP; DC Tech | 8h |
| 766 | 3.19.5.6 | Reconnect Water Lines | 0.5d | 2002-10-30 | 2002-10-30 | 765 | 3.75d | 0d | PEP; DC Tech | 8h |
| 767 | 3.19.5.7 | Reconnect Fibers | 0.1d | 2002-10-30 | 2002-10-30 | 766 | 3.75d | 0d | PEP; DC Tech | 1.6h |
| 768 | 3.19.5.8 | Reconnect Environmental Cables | 0.1d | 2002-10-30 | 2002-10-31 | 767 | 3.75d | 0d | PEP; DC Tech | 1.6h |
| 769 | 3.19.5.9 | Reconnect Extender Lines | 0.25d | 2002-10-31 | 2002-10-31 | 768 | 3.75d | 0d | PEP; DC Tech | 4h |
| 770 | 3.19.5.10 | Reconnect Gas Lines at Back of Raft | 0.25d | 2002-10-31 | 2002-10-31 | 769 | 3.75d | 0d | PEP; DC Tech | 4h |
| 771 | 3.19.5.11 | Reconnect Water Lines at Back of Raft | 0.25d | 2002-10-31 | 2002-10-31 | 770 | 3.75d | 1.35d | PEP; DC Tech | 4h |
| 772 | 3.19.6 | **Reconnect Beamlines in Tunnel to -15m from IP** | 12.5d | 2002-10-18 | 2002-11-05 |  | 5.95d |  | PEP | 594h |
| 773 | 3.19.6.1 | Reinstall BV1 Raft | 1d | 2002-10-18 | 2002-10-21 | 743 | 5.95d | 0d | PEP; Riggers; MFD | 24h |
| 774 | 3.19.6.2 | Align BV1 Raft | 1d | 2002-10-21 | 2002-10-22 | 773 | 5.95d | 0d | PEP; ALIGN | 16h |
| 775 | 3.19.6.3 | Reconnect Power, Water, TC & Klixons to BV1 Raft | 4d | 2002-10-22 | 2002-10-28 | 774 | 14.45d |  | PEP; MFD; PC | 96h |
| 776 | 3.19.6.4 | Reinstall Corrector and Support Table | 0.25d | 2002-10-22 | 2002-10-22 | 774 | 5.95d | 0d | PEP; MFD | 4h |
| 777 | 3.19.6.5 | Reinstall Collimator Support Table | 0.25d | 2002-10-22 | 2002-10-22 | 776 | 17.95d |  | PEP; MFD | 4h |
| 778 | 3.19.6.6 | Reinstall Lumi Monitor Chamber | 0.25d | 2002-10-22 | 2002-10-22 | 776 | 5.95d | 0d | PEP; MFD | 4h |
| 779 | 3.19.6.7 | Reinstall Collimator | 1d | 2002-10-22 | 2002-10-23 | 778 | 5.95d | 0d | PEP; MFD | 16h |
| 780 | 3.19.6.8 | Align Lumi Monitor Chamber and Collimator | 1d | 2002-10-23 | 2002-10-24 | 779 | 5.95d | 0d | PEP; ALIGN | 16h |
| 781 | 3.19.6.9 | Install Backward Frangible Link | 2d | 2002-10-24 | 2002-10-28 | 780 | 13.95d |  | PEP; MFD | 32h |
| 782 | 3.19.6.10 | Reinstall Lumi Monitor Counters & Lead Shielding | 2d | 2002-10-24 | 2002-10-28 | 780 | 11.95d | 0d | PEP; C. Field; MFD | 48h |
| 783 | 3.19.6.11 | Reconnect Lumi Monitor Cables and Electronics | 2d | 2002-10-28 | 2002-10-30 | 782 | 11.95d |  | PEP; C. Field | 32h |
| 784 | 3.19.6.12 | Reconnect Water, Controls & TC to Collimator | 1d | 2002-10-24 | 2002-10-25 | 780 | 13.45d | 0d | PEP; MFD | 16h |
| 785 | 3.19.6.13 | Reinstall Lead Collimator Shielding | 1.5d | 2002-10-25 | 2002-10-29 | 784 | 13.45d |  | PEP; MFD | 24h |
| 786 | 3.19.6.14 | Reinstall & Align LER & HER Beamlines, Pumps, Valves | 6d | 2002-10-24 | 2002-11-01 | 780 | 5.95d | 0d | PEP; ALIGN; MFD | 144h |
| 787 | 3.19.6.15 | Reconnect Power, Water & TC to LER & HER Beamlines | 2d | 2002-11-01 | 2002-11-05 | 786 | 5.95d | 0d | PEP; MFD | 32h |

Notes:
- 776: Remove top and sides of corrector prior to lowering in Luminosity monitor

| ID | WBS | Task | Type | Duration | Start | Finish | Predecessors | Total slack | Free slack | Constraint | Resources | Work |
| --- | --- | --- | --- | --- | --- | --- | --- | --- | --- | --- | --- | --- |
| 788 | 3.19.6.16 | **Vacuum Pumpdown and systems test** |  | 7d | 2002-11-04 | 2002-11-13 |  | 2.4d |  |  | PEP; MFD | 256h |
| 789 | 3.19.6.18 | Reinstall Lead Frangible Link Shielding |  | 1d | 2002-11-05 | 2002-11-06 | 787 | 5.95d | 0d |  | PEP; MFD | 16h |
| 790 | 3.19.6.19 | Reinstall Lead Beamline Shielding |  | 1d | 2002-11-06 | 2002-11-07 | 789 | 5.95d | 5.7d |  | PEP; MFD | 16h |
| 792 | 3.20 | Test All Systems (Day Shift) |  | 7d | 2002-11-04 | 2002-11-13 | 759, 771 | 2.4d | 2.15d |  | PEP; MFD; SVT Tech; DC Tech | 224h |
| 793 | 3.21 | IR-2 PPS Certification (Swing Shift) |  | 4d | 2002-11-11 | 2002-11-14 |  | 0d |  | start no earlier than 2002-11-11 | PEP; P.Bong | 64h |
| 794 | 3.22 | PEP Upgrade Complete | milestone | 0d | 2002-11-15 | 2002-11-15 | 792, 790, 734 | 0.25d |  |  | PEP |  |
| 796 | 4 | **BABAR WORK, PHASE 4 (Post Shutdown Tasks)** |  | 30.95d | 2002-08-23 | 2002-10-07 |  | 28.6d |  |  | BBR | 1358.8h |
| 797 | 4.1 | **Super Heat Exchanger** |  | 30.95d | 2002-08-23 | 2002-10-07 |  | 28.6d |  |  | BBR; SHE | 1111.2h |
| 798 | 3.18.1.5 | Install Piping from Water Valve Panel to Backup Heat Exchanger (Racine) |  | 15d | 2002-08-23 | 2002-09-13 | 303 | 43d | 0d |  | CRYO; SHE; BBR | 360h |
| 799 | 3.18.1.6 | Test EMC Backup Fluorinert Circuit |  | 2d | 2002-09-16 | 2002-09-17 | 798 | 43d |  |  | SHE; EMC; BBR; CRYO | 64h |
| 800 | 3.18.1.7 | Test EMC Backup Water Circuit |  | 2d | 2002-09-16 | 2002-09-17 | 798 | 43d |  |  | SHE; EMC; BBR; CRYO | 64h |
| 801 | 3.18.1.8 | Test DIRC Backup Water Circuit |  | 2d | 2002-09-16 | 2002-09-17 | 798 | 43d |  |  | SHE; DIRC; BBR; CRYO | 64h |
| 802 | 3.18.1.9 | Test Drift Chamber Backup Cicuits |  | 2d | 2002-09-16 | 2002-09-17 | 798 | 43d |  |  | SHE; DCH; BBR; CRYO | 64h |
| 807 | 4.1.6 | **Modifications to F.C extraction system** |  | 19.95d | 2002-09-10 | 2002-10-07 |  | 28.6d |  |  |  |  |
| 808 | 4.1.6.1 | Manufacture new parts |  | 7d | 2002-09-10 | 2002-09-18 |  | 29.5d | 0d | start no earlier than 2002-09-10 |  |  |
| 809 | 4.1.6.2 | Modify (extend) extension table |  | 5d | 2002-09-19 | 2002-09-25 | 808 | 29.5d | 0d |  |  |  |
| 810 | 4.1.6.3 | Load test extension table |  | 1d | 2002-09-26 | 2002-09-26 | 809 | 29.5d | 0.45d |  |  |  |
| 811 | 4.1.6.4 | Open forward doors |  | 0.6d | 2002-09-10 | 2002-09-10 |  | 29.05d | 0d | start no earlier than 2002-09-10 |  |  |
| 812 | 4.1.6.5 | Mark and disconnect cooling plates |  | 0.5d | 2002-09-10 | 2002-09-11 | 811 | 29.05d | 0d |  |  |  |
| 813 | 4.1.6.6 | Remove pedestal top plate |  | 0.25d | 2002-09-11 | 2002-09-11 | 812 | 29.05d | 0d |  |  |  |
| 814 | 4.1.6.7 | Remove load cell readout box and cables |  | 0.25d | 2002-09-11 | 2002-09-11 | 813 | 29.05d | 0d |  |  |  |
| 815 | 4.1.6.8 | Remove bridge |  | 0.5d | 2002-09-11 | 2002-09-12 | 814 | 29.05d | 0d |  |  |  |
| 816 | 4.1.6.9 | Remove jack interconnect drive |  | 0.25d | 2002-09-12 | 2002-09-12 | 815 | 29.05d | 0d |  |  |  |
| 817 | 4.1.6.10 | Remove drive arm |  | 0.1d | 2002-09-12 | 2002-09-12 | 816 | 29.05d | 0d |  |  |  |
| 818 | 4.1.6.11 | Modify (shorten) drive arm |  | 2d | 2002-09-12 | 2002-09-16 | 817 | 37.8d | 8.75d |  |  |  |
| 819 | 4.1.6.12 | Remove screw drive |  | 0.2d | 2002-09-12 | 2002-09-12 | 817 | 29.05d | 0d |  |  |  |
| 820 | 4.1.6.13 | Modify screw drive handwheel |  | 2d | 2002-09-12 | 2002-09-16 | 819 | 35.75d | 6.7d |  |  |  |
| 821 | 4.1.6.14 | Remove Duff Norton jacks and load cells |  | 0.25d | 2002-09-12 | 2002-09-12 | 819 | 29.05d | 0d |  |  |  |
| 822 | 4.1.6.15 | Replace load cells #1 and #2 |  | 1d | 2002-09-12 | 2002-09-13 | 821 | 40.1d | 11.05d |  |  |  |
| 823 | 4.1.6.16 | Remove cross brace (note shim locations) |  | 0.25d | 2002-09-12 | 2002-09-13 | 821 | 29.05d | 0d |  |  |  |
| 824 | 4.1.6.17 | Remove bearing blocks |  | 0.1d | 2002-09-13 | 2002-09-13 | 823 | 29.05d | 0d |  |  |  |
| 825 | 4.1.6.18 | Remove upper 'Y' support beam (note shim positions) |  | 0.5d | 2002-09-13 | 2002-09-13 | 824 | 29.05d | 0d |  |  |  |
| 826 | 4.1.6.19 | Remove 'H' beam |  | 0.5d | 2002-09-13 | 2002-09-16 | 825 | 29.05d | 0d |  |  |  |
| 827 | 4.1.6.20 | Modify (shorten) 'H' beam |  | 5d | 2002-09-16 | 2002-09-23 | 826 | 29.05d | 0d |  |  |  |
| 828 | 4.1.6.21 | Modify (cut in place) pads on pedestal |  | 1d | 2002-09-16 | 2002-09-17 | 826 | 33.05d | 4d |  |  |  |
| 829 | 4.1.6.22 | Install 'H' beam |  | 1d | 2002-09-23 | 2002-09-24 | 828, 827 | 29.05d | 0d |  |  |  |
| 830 | 4.1.6.23 | Install new spacer block to 'H' beam |  | 0.1d | 2002-09-24 | 2002-09-24 | 829 | 29.05d | 0d |  |  |  |
| 831 | 4.1.6.24 | Level 'H' beam |  | 0.5d | 2002-09-24 | 2002-09-24 | 830 | 29.05d | 0d |  |  |  |
| 832 | 4.1.6.25 | Mark through and drill new holes in pads |  | 0.5d | 2002-09-24 | 2002-09-25 | 831 | 29.05d | 0d |  |  |  |
| 833 | 4.1.6.26 | Install screw drive and modified handwheel |  | 1d | 2002-09-25 | 2002-09-26 | 832, 820 | 29.05d | 0d |  |  |  |
| 834 | 4.1.6.27 | Install upper 'Y' beam |  | 0.5d | 2002-09-26 | 2002-09-26 | 833 | 29.05d | 0d |  |  |  |
| 835 | 4.1.6.28 | Install bearing blocks |  | 0.1d | 2002-09-26 | 2002-09-26 | 834 | 29.05d | 0d |  |  |  |
| 836 | 4.1.6.29 | Install cross brace (including shims) |  | 0.25d | 2002-09-26 | 2002-09-27 | 835 | 29.05d | 0d |  |  |  |
| 837 | 4.1.6.30 | Install drive arm |  | 0.25d | 2002-09-27 | 2002-09-27 | 836, 818 | 29.05d | 0d |  |  |  |
| 838 | 4.1.6.31 | Install extension table |  | 0.5d | 2002-09-27 | 2002-09-27 | 810, 837 | 29.05d | 0d |  |  |  |
| 839 | 4.1.6.32 | Align drive arm and screw drive |  | 1d | 2002-09-27 | 2002-09-30 | 838 | 29.05d | 0d |  |  |  |
| 840 | 4.1.6.33 | Install Duff Norton jacks and load cells |  | 0.5d | 2002-09-30 | 2002-10-01 | 839, 822 | 29.05d | 0d |  |  |  |
| 841 | 4.1.6.34 | Install bridge |  | 0.75d | 2002-10-01 | 2002-10-02 | 840 | 29.05d | 0d |  |  |  |
| 842 | 4.1.6.35 | Align jacks and bolt up bridge |  | 0.25d | 2002-10-02 | 2002-10-02 | 841 | 29.05d | 0d |  |  |  |
| 843 | 4.1.6.36 | Install seismic braces to bridge |  | 1d | 2002-10-02 | 2002-10-03 | 842 | 29.05d | 0d |  |  |  |
| 844 | 4.1.6.37 | Install pedestal top plate |  | 1d | 2002-10-03 | 2002-10-04 | 843 | 29.05d | 0d |  |  |  |
| 845 | 4.1.6.38 | Install Blue frames |  | 0.25d | 2002-10-04 | 2002-10-04 | 844 | 29.05d | 0d |  |  |  |
| 846 | 4.1.6.39 | Rollout to within 4" of BaBar and test system. Roll back |  | 1d | 2002-10-04 | 2002-10-07 | 845 | 29.05d | 0d |  |  |  |
| 847 | 4.1.6.40 | Install ST temporary support and pads |  | 0.25d | 2002-10-07 | 2002-10-07 | 846 | 29.05d | 0d |  |  |  |
| 848 | 4.1.7 | System ready for support tube installation | milestone | 0d | 2002-10-07 | 2002-10-07 | 847 | 29.05d |  |  |  |  |
